# DIAGRAMA GRANTT EFRAIN ARCAYA

Schedule from MS Project, 2023-02-01 to 2025-01-30, costs in S..

## Calendars

- Estándar: Mon-Sat 08:00-13:00, 14:00-17:00; Sun off.

## Schedule

| ID | WBS | Task | Type | Duration | Start | Finish | Predecessors | Total slack | Free slack | Cost | Text1 |
| --- | --- | --- | --- | --- | --- | --- | --- | --- | --- | --- | --- |
| 1 | 1 | **MEJORAMIENTO DEL SERVICIO DE EDUCACIÓN BASICA REGULAR DE LA INSTITUCION EDUCATIVA N° 093 EFRAIN ARCAYA ZEVALLOS DEL DISTRITO DE ZARUMILLA- PROVINCIA DE ZARUMILLA-DEPARTAMENTO DE TUMBES** |  | 626d | 2023-02-01 | 2025-01-30 |  | 0d |  | 30,757,713.39 |  |
| 2 | 1.1 | INICIO DEL PROYECTO | milestone | 0d | 2023-02-01 | 2023-02-01 |  | 0d |  |  |  |
| 3 | 1.2 | **OBRAS PROVISIONALES Y PRELIMINARES** |  | 600d | 2023-02-01 | 2024-12-31 |  | 6d |  | 1,503,863.09 | 01 |
| 4 | 1.2.1 | **OBRAS PROVISIONALES** |  | 7d | 2023-02-01 | 2023-02-08 |  | 619d |  | 19,962.62 | 01.01 |
| 5 | 1.2.1.1 | SUMINISTRO Y COLOCACION DE CARTEL DE OBRA DE 2.40 x 3.60m |  | 1d | 2023-02-01 | 2023-02-01 | 2 | 619d | 0d | 850.44 | 01.01.01 |
| 6 | 1.2.1.2 | CASETA DE GUARDIANIA Y/O ALMACEN |  | 6d | 2023-02-02 | 2023-02-08 | 5 | 619d | 0d | 3,520.32 | 01.01.02 |
| 7 | 1.2.1.3 | COMEDOR PARA PERSONAL OBRERO |  | 6d | 2023-02-02 | 2023-02-08 | 6SS | 619d | 0d | 4,400.4 | 01.01.03 |
| 8 | 1.2.1.4 | VESUARIO PARA PERSONAL |  | 6d | 2023-02-02 | 2023-02-08 | 7SS | 619d | 0d | 880.08 | 01.01.04 |
| 9 | 1.2.1.5 | CERCO PROVISIONAL EN OBRA DE CALAMINA GALVANIZADA h=2.20m |  | 6d | 2023-02-02 | 2023-02-08 | 8SS | 619d |  | 10,311.38 | 01.01.05 |
| 10 | 1.2.2 | **TRABAJOS PRELIMINARES** |  | 301d | 2023-02-08 | 2024-01-24 |  | 0d |  | 353,399.64 | 01.02 |
| 11 | 1.2.2.1 | TRAZO, NIVELES Y REPLANTEO |  | 300d | 2023-02-09 | 2024-01-24 | 12SS+1d | 0d |  | 36,883.04 | 01.02.01 |
| 12 | 1.2.2.2 | LIMPIEZA INICIAL DE OBRA |  | 35d | 2023-02-08 | 2023-03-20 | 2SS+6d | 0d |  | 19,499.64 | 01.02.02 |
| 13 | 1.2.2.3 | MOVILIZACION Y DESMOVILIZACION DE EQUIPO |  | 90d | 2023-02-09 | 2023-05-24 | 11SS | 529d |  | 9,596.8 | 01.02.03 |
| 14 | 1.2.2.4 | TALA DE ARBOLES INC/REFORESTACION |  | 6d | 2023-02-10 | 2023-02-16 | 12SS+2d | 612d |  | 11,551.5 | 01.02.04 |
| 15 | 1.2.2.5 | **SERVICIOS HIGIENICOS PROVISIONALES** |  | 14d | 2023-02-09 | 2023-02-24 |  | 586d |  | 28,089.91 | 01.02.05 |
| 16 | 1.2.2.5.1 | CAPA DE MATERIAL DE PRESTAMO - HORMIGON e=0.20m CON EQUIPO LIVIANO |  | 1d | 2023-02-09 | 2023-02-09 | 11SS | 586d | 0d | 508.11 | 01.02.05.01 |
| 17 | 1.2.2.5.2 | LOSA DE CONCRETO F'C=140 KG/CM2, e=10cm/ACABADO FROTACHADO (INC. ENCOFRADO) |  | 1d | 2023-02-18 | 2023-02-18 | 78 | 586d | 0d | 1,531.24 | 01.02.05.02 |
| 18 | 1.2.2.5.3 | SARDINEL DE CONCRETO (0.20x0.40 ) F'C=140 KG/CM2 |  | 1d | 2023-02-18 | 2023-02-18 | 17SS | 586d | 0d | 853.48 | 01.02.05.03 |
| 19 | 1.2.2.5.4 | SUMINISTRO E INSTALACION DE COLUMNAS DE MADERA DE 4" x 4" |  | 6d | 2023-02-18 | 2023-02-24 | 18SS | 605d | 0d | 3,607.97 | 01.02.05.04 |
| 20 | 1.2.2.5.5 | SUMINISTRO E INSTALACION DE PANELES DE FIBRO CEMENTO ST DE 6mm |  | 6d | 2023-02-18 | 2023-02-24 | 19SS | 605d |  | 7,726.73 | 01.02.05.05 |
| 21 | 1.2.2.5.6 | SUMINISTRO E INSTALACION DE VIGAS DE MADERA DE 2" x 4" |  | 6d | 2023-02-18 | 2023-02-24 | 18SS | 586d | 0d | 429.08 | 01.02.05.06 |
| 22 | 1.2.2.5.7 | PLANCHAS DE PROLIPROPILENO DE e=1.2mm/COLOR ROJO - INCLUYE CORREAS DE MADERA 2" x 2" |  | 6d | 2023-02-18 | 2023-02-24 | 21SS | 586d | 0d | 1,016.45 | 01.02.05.07 |
| 23 | 1.2.2.5.8 | SUMINISTRO E INSTALACION DE PUERTAS DE TRIPLAY CON MARCO DE MADERA (0.90x2.10) INCL. CERRAJERIA |  | 6d | 2023-02-18 | 2023-02-24 | 22SS | 586d | 0d | 760 | 01.02.05.08 |
| 24 | 1.2.2.5.9 | SUMINISTRO E INSTALACION DE PUERTAS DE TRIPLAY CON MARCO DE MADERA (0.60x1.60) INCL. CERRAJERIA |  | 6d | 2023-02-18 | 2023-02-24 | 23SS | 586d | 0d | 720 | 01.02.05.09 |
| 25 | 1.2.2.5.10 | SUMINISTRO Y COLOCACION DE VENTANAS (2.00x0.60m) INC. CELOCIA Y MARCO DE MADERA |  | 6d | 2023-02-18 | 2023-02-24 | 24SS | 586d | 0d | 220 | 01.02.05.10 |
| 26 | 1.2.2.5.11 | SARD. DE Cº 0.20x0.50 F'C=140 KG/CM2 |  | 6d | 2023-02-18 | 2023-02-24 | 25SS | 586d | 0d | 503.74 | 01.02.05.11 |
| 27 | 1.2.2.5.12 | TARRAJEO DE SARD. DE Cº 0.20x0.50 |  | 6d | 2023-02-18 | 2023-02-24 | 26SS | 586d | 0d | 245.75 | 01.02.05.12 |
| 28 | 1.2.2.5.13 | PINTURA CON ESMALTE SINTETICO |  | 6d | 2023-02-18 | 2023-02-24 | 27SS | 586d | 0d | 914.78 | 01.02.05.13 |
| 29 | 1.2.2.5.14 | LAVADERO DE UNA POZA ACABADO PULIDO INC./INSTALACIONES |  | 6d | 2023-02-18 | 2023-02-24 | 28SS | 586d | 0d | 520 | 01.02.05.14 |
| 30 | 1.2.2.5.15 | COLOCACION DE TORRE METALICA PARA TANQUE DE AGUA SEGUN DISEÑO |  | 6d | 2023-02-18 | 2023-02-24 | 29SS | 586d | 0d | 1,700 | 01.02.05.15 |

| ID | WBS | Task | Duration | Start | Finish | Predecessors | Total slack | Free slack | Cost | Text1 |
| --- | --- | --- | --- | --- | --- | --- | --- | --- | --- | --- |
| 31 | 1.2.2.5.16 | **APARATOS SANITARIOS Y ACCESORIOS** | 6d | 2023-02-18 | 2023-02-24 |  | 586d |  | 2,276.35 | 01.02.05.16 |
| 32 | 1.2.2.5.16.1 | SUMINISTRO DE APARATOS SANITARIO (INODORO) | 6d | 2023-02-18 | 2023-02-24 | 30SS | 586d | 0d | 1,258.47 | 01.02.05.16.01 |
| 33 | 1.2.2.5.16.2 | SUMINISTRO DE APARATOS SANITARIOS (DUCHAS) | 6d | 2023-02-18 | 2023-02-24 | 32SS | 586d | 0d | 188.7 | 01.02.05.16.02 |
| 34 | 1.2.2.5.16.3 | SUMINISTRO DE ACCESORIOS P/INODOROS | 6d | 2023-02-18 | 2023-02-24 | 33SS | 586d | 0d | 95.94 | 01.02.05.16.03 |
| 35 | 1.2.2.5.16.4 | SUMINISTRO DEACCESORIOS P/DUCHAS | 6d | 2023-02-18 | 2023-02-24 | 34SS | 586d | 0d | 0.54 | 01.02.05.16.04 |
| 36 | 1.2.2.5.16.5 | INSTALACION DE APARATOS SANITARIOS Y ACCESORIOS | 6d | 2023-02-18 | 2023-02-24 | 35SS | 586d | 0d | 732.7 | 01.02.05.16.05 |
| 37 | 1.2.2.5.17 | **SISTEMA DE AGUA FRIA** | 3d | 2023-02-10 | 2023-02-13 |  | 586d |  | 463.2 | 01.02.05.17 |
| 38 | 1.2.2.5.17.1 | SALIDA DE AGUA FRIA Ø 1/2" BRONCE | 3d | 2023-02-10 | 2023-02-13 | 16 | 586d | 0d | 463.2 | 01.02.05.17.01 |
| 39 | 1.2.2.5.18 | **REDES DE DISTRIBUCION** | 3d | 2023-02-10 | 2023-02-13 |  | 586d |  | 255.39 | 01.02.05.18 |
| 40 | 1.2.2.5.18.1 | TUBERIA PVC CLASE 10 SP P/AGUA FRIA D=3/4" | 3d | 2023-02-10 | 2023-02-13 | 38SS | 586d | 0d | 255.39 | 01.02.05.18.01 |
| 41 | 1.2.2.5.19 | **REDES DE ALIMENTACION** | 3d | 2023-02-10 | 2023-02-13 |  | 586d |  | 22.71 | 01.02.05.19 |
| 42 | 1.2.2.5.19.1 | TUBERIA PVC CLASE 10 SP P/AGUA FRIA D=3/4" | 3d | 2023-02-10 | 2023-02-13 | 40SS | 586d | 0d | 22.71 | 01.02.05.19.01 |
| 43 | 1.2.2.5.20 | **ACCESORIOS DE REDES DE AGUA** | 3d | 2023-02-10 | 2023-02-13 |  | 586d |  | 758.03 | 01.02.05.20 |
| 44 | 1.2.2.5.20.1 | SUMINISTRO E INSTALACION DE CODO DE 90° PVC AGUA C-10 3/4" | 3d | 2023-02-10 | 2023-02-13 | 42SS | 586d | 0d | 170.85 | 01.02.05.20.01 |
| 45 | 1.2.2.5.20.2 | SUMINISTRO E INSTALACION DE TEE PVC SAP DE Ø 1" | 3d | 2023-02-10 | 2023-02-13 | 44SS | 586d | 0d | 19.98 | 01.02.05.20.02 |
| 46 | 1.2.2.5.20.3 | SUMINISTRO E INSTALACION DE TEE PVC AGUA C-10 3/4" | 3d | 2023-02-10 | 2023-02-13 | 45SS | 586d | 0d | 87.84 | 01.02.05.20.03 |
| 47 | 1.2.2.5.20.4 | SUMINISTRO E INSTALACION DE CODO DE BRONCE 1/2" | 3d | 2023-02-10 | 2023-02-13 | 46SS | 586d | 0d | 99.6 | 01.02.05.20.04 |
| 48 | 1.2.2.5.20.5 | SUMINISTRO E INSTALACION DE ADAPTADOR PVC AGUA C-10 3/4" | 3d | 2023-02-10 | 2023-02-13 | 47SS | 586d | 0d | 86.1 | 01.02.05.20.05 |
| 49 | 1.2.2.5.20.6 | SUMINISTRO E INSTALACION DE NIPLE PVC AGUA C-10 3/4" | 3d | 2023-02-10 | 2023-02-13 | 48SS | 586d | 0d | 38.88 | 01.02.05.20.06 |
| 50 | 1.2.2.5.20.7 | SUMINISTRO E INSTALACION DE REDUCCION PVC AGUA C-10 1" A 3/4" | 3d | 2023-02-10 | 2023-02-13 | 49SS | 586d | 0d | 10.5 | 01.02.05.20.07 |
| 51 | 1.2.2.5.20.8 | SUMINISTRO E INSTALACION DE REDUCCION PVC AGUA C-10 3/4 A 1/2" | 3d | 2023-02-10 | 2023-02-13 | 50SS | 586d | 0d | 89.4 | 01.02.05.20.08 |
| 52 | 1.2.2.5.20.9 | SUMINISTRO E INSTALACION DE TUBO DE ABASTO PARA INODORO | 3d | 2023-02-10 | 2023-02-13 | 51SS | 586d | 0d | 91.56 | 01.02.05.20.09 |
| 53 | 1.2.2.5.20.10 | SUMINISTRO E INSTALACION DE TRAMPA PLASTICA C/REGISTRO | 3d | 2023-02-10 | 2023-02-13 | 52SS | 586d | 0d | 30.52 | 01.02.05.20.10 |
| 54 | 1.2.2.5.20.11 | SUMINISTRO E INSTALACION DE UNION UNIVERSAL PVC 3/4" | 3d | 2023-02-10 | 2023-02-13 | 53SS | 586d | 0d | 32.8 | 01.02.05.20.11 |

| ID | WBS | Task | Duration | Start | Finish | Predecessors | Total slack | Free slack | Cost | Text1 |
| --- | --- | --- | --- | --- | --- | --- | --- | --- | --- | --- |
| 55 | 1.2.2.5.21 | **VALVULAS** | 3d | 2023-02-10 | 2023-02-13 |  | 586d |  | 85.97 | 01.02.05.21 |
| 56 | 1.2.2.5.21.1 | VALVULA COMPUERTA PESADA DE BRONCE DE 3/4" | 3d | 2023-02-10 | 2023-02-13 | 54SS | 586d | 0d | 85.97 | 01.02.05.21.01 |
| 57 | 1.2.2.5.22 | **ALMACENAMIENTO DE AGUA** | 3d | 2023-02-14 | 2023-02-16 |  | 586d |  | 1,874.35 | 01.02.05.22 |
| 58 | 1.2.2.5.22.1 | SUMINISTRO E INSTALACION DE TANQUE DE POLIETILENO CAP. 1100 LT | 3d | 2023-02-14 | 2023-02-16 | 56 | 586d | 0d | 767.26 | 01.02.05.22.01 |
| 59 | 1.2.2.5.22.2 | SUMINISTRO E INSTALACION DE CISTERNA DE POLIETILENO CAP. 1200 LT | 3d | 2023-02-14 | 2023-02-16 | 58SS | 586d | 0d | 1,107.09 | 01.02.05.22.02 |
| 60 | 1.2.2.5.23 | **DESAGUE Y VENTILACION** | 3d | 2023-02-15 | 2023-02-17 |  | 586d |  | 367.59 | 01.02.05.23 |
| 61 | 1.2.2.5.23.1 | SALIDAS DE DESAGUE DE PVC 4" | 3d | 2023-02-15 | 2023-02-17 | 59SS+1d | 586d | 0d | 159.54 | 01.02.05.23.01 |
| 62 | 1.2.2.5.23.2 | SALIDAS DE DESAGUE DE PVC 2" | 3d | 2023-02-15 | 2023-02-17 | 61SS | 586d | 0d | 208.05 | 01.02.05.23.02 |
| 63 | 1.2.2.5.24 | **REDES DE DERIVACION** | 3d | 2023-02-15 | 2023-02-17 |  | 586d |  | 174.4 | 01.02.05.24 |
| 64 | 1.2.2.5.24.1 | TUBO DE DESAGUE DE PVC Ø 4" | 3d | 2023-02-15 | 2023-02-17 | 62SS | 586d | 0d | 107.76 | 01.02.05.24.01 |
| 65 | 1.2.2.5.24.2 | TUBO DE DESAGUE DE PVC Ø 2" | 3d | 2023-02-15 | 2023-02-17 | 64SS | 586d | 0d | 66.64 | 01.02.05.24.02 |
| 66 | 1.2.2.5.25 | **REDES COLECTORAS** | 3d | 2023-02-15 | 2023-02-17 |  | 586d |  | 84.32 | 01.02.05.25 |
| 67 | 1.2.2.5.25.1 | TUBERIA DE DESAGUE PVC SAP D= 4" | 3d | 2023-02-15 | 2023-02-17 | 65SS | 586d | 0d | 84.32 | 01.02.05.25.01 |
| 68 | 1.2.2.5.26 | **ACCESORIOS DE REDES DE DESAGUE** | 3d | 2023-02-15 | 2023-02-17 |  | 586d |  | 340.32 | 01.02.05.26 |
| 69 | 1.2.2.5.26.1 | SUMINISTRO E INSTALACION DE CODO 90° PVC Ø 4" | 3d | 2023-02-15 | 2023-02-17 | 67SS | 586d | 0d | 23.44 | 01.02.05.26.01 |
| 70 | 1.2.2.5.26.2 | SUMINISTRO E INSTALACION DE CODO 90° PVC Ø 2" | 3d | 2023-02-15 | 2023-02-17 | 69SS | 586d | 0d | 27.54 | 01.02.05.26.02 |
| 71 | 1.2.2.5.26.3 | SUMINISTRO E INSTALACION DE REGISTRO DE BRONCE DE Ø 4" | 3d | 2023-02-15 | 2023-02-17 | 70SS | 586d | 0d | 14.05 | 01.02.05.26.03 |
| 72 | 1.2.2.5.26.4 | SUMINISTRO Y COLOCACION DE SUMIDERO CON TRAMPA P | 3d | 2023-02-15 | 2023-02-17 | 71SS | 586d | 0d | 104 | 01.02.05.26.04 |
| 73 | 1.2.2.5.26.5 | SUMINISTRO E INSTALACION DE TEE PVC 4" | 3d | 2023-02-15 | 2023-02-17 | 72SS | 586d | 0d | 16.42 | 01.02.05.26.05 |
| 74 | 1.2.2.5.26.6 | SUMINISTRO E INSTALACIÓN DE YEE SIMPLE 4" | 3d | 2023-02-15 | 2023-02-17 | 73SS | 586d | 0d | 47.73 | 01.02.05.26.06 |
| 75 | 1.2.2.5.26.7 | SUMINISTRO E INSTALACIÓN DE YEE DE 4" A 2" | 3d | 2023-02-15 | 2023-02-17 | 74SS | 586d | 0d | 81.65 | 01.02.05.26.07 |
| 76 | 1.2.2.5.26.8 | SUMINISTRO E INSTALACIÓN DE SOMBRERO DE VENTILACION 4" | 3d | 2023-02-15 | 2023-02-17 | 75SS | 586d | 0d | 25.49 | 01.02.05.26.08 |
| 77 | 1.2.2.5.27 | **CAMARAS DE INSPECCION** | 3d | 2023-02-15 | 2023-02-17 |  | 586d |  | 129.95 | 01.02.05.27 |
| 78 | 1.2.2.5.27.1 | SUMINISTRO E INSTALACION DE CAJA DE REGISTRO | 3d | 2023-02-15 | 2023-02-17 | 76SS | 586d | 0d | 129.95 | 01.02.05.27.01 |

| ID | WBS | Task | Duration | Start | Finish | Predecessors | Total slack | Free slack | Cost | Text1 |
| --- | --- | --- | --- | --- | --- | --- | --- | --- | --- | --- |
| 79 | 1.2.2.6 | **DEMOLICION Y DESMONTAJE** | 25d | 2023-02-18 | 2023-03-18 |  | 586d |  | 247,778.75 | 01.02.06 |
| 80 | 1.2.2.6.1 | DEMOLICION DE EDIFICACION EXISTENTE C/MAQUINARIA | 25d | 2023-02-18 | 2023-03-18 | 36SS | 586d | 0d | 168,346.82 | 01.02.06.01 |
| 81 | 1.2.2.6.2 | DEMOLICION MANUAL DE CUNETAS EXISTENTES | 25d | 2023-02-18 | 2023-03-18 | 80SS | 586d | 0d | 4,171.23 | 01.02.06.02 |
| 82 | 1.2.2.6.3 | DESMONTAJE DE APARATOS SANITARIOS EXISTENTES, MANUAL | 25d | 2023-02-18 | 2023-03-18 | 81SS | 586d | 0d | 83.2 | 01.02.06.03 |
| 83 | 1.2.2.6.4 | DESMONTAJE DE COBERTURA EN EDIFICACION EXISTENTE | 25d | 2023-02-18 | 2023-03-18 | 82SS | 586d | 0d | 14,777.55 | 01.02.06.04 |
| 84 | 1.2.2.6.5 | DESMONTAJE DE CERCO, VENTANAS Y PUERTAS METALICAS | 25d | 2023-02-18 | 2023-03-18 | 83SS | 586d | 0d | 10,567.58 | 01.02.06.05 |
| 85 | 1.2.2.6.6 | DESMONTAJE DE AULA DE DRYWALL EXISTENTE MANUAL | 25d | 2023-02-18 | 2023-03-18 | 84SS | 586d | 0d | 3,656.46 | 01.02.06.06 |
| 86 | 1.2.2.6.7 | DESMONTAJE MANUA DE AULA PREFABRICADA DE MATERIAL TERMICO INC. PUERTAS Y VENTANAS | 25d | 2023-02-18 | 2023-03-18 | 85SS | 586d | 0d | 29,263.74 | 01.02.06.07 |
| 87 | 1.2.2.6.8 | DESMONTAJE MANUAL DE ESTRUCTURA METALICA PARA COBERTURA DE MALLA RASCHELL EXISTENTE | 25d | 2023-02-18 | 2023-03-18 | 86SS | 586d | 0d | 1,187.55 | 01.02.06.08 |
| 88 | 1.2.2.6.9 | DESMONTAJE DE CANTONERAS METALICAS EXISTENTE, MANUAL | 25d | 2023-02-18 | 2023-03-18 | 87SS | 586d | 0d | 388.8 | 01.02.06.09 |
| 89 | 1.2.2.6.10 | DESMONTAJE DE PASAMANOS METALICOS EXISTENTES, MANUAL | 25d | 2023-02-18 | 2023-03-18 | 88SS | 586d | 0d | 81.7 | 01.02.06.10 |
| 90 | 1.2.2.6.11 | DESMONTAJE DE GRUTAS Y BUSTOS EXISTENTE MANUAL | 25d | 2023-02-18 | 2023-03-18 | 89SS | 586d | 0d | 554.56 | 01.02.06.11 |
| 91 | 1.2.2.6.12 | DESMONTAJE DE ASTA DE BANDERA EXISTENTE, MANUAL | 25d | 2023-02-18 | 2023-03-18 | 90SS | 586d | 0d | 685.6 | 01.02.06.12 |
| 92 | 1.2.2.6.13 | DESMONTAJE DE DEPOSITO PARA BASURA EXISTENTE, MANUAL | 25d | 2023-02-18 | 2023-03-18 | 91SS | 586d | 0d | 92.34 | 01.02.06.13 |
| 93 | 1.2.2.6.14 | DESMONTAJE DE PARANTES DE MADERA EXISTENTE, MANUAL | 25d | 2023-02-18 | 2023-03-18 | 92SS | 586d | 0d | 277.28 | 01.02.06.14 |
| 94 | 1.2.2.6.15 | DESMONTAJE DE TIJERALES METALICOS EXISTENTES, MANUAL | 25d | 2023-02-18 | 2023-03-18 | 93SS | 586d | 0d | 1,778.04 | 01.02.06.15 |
| 95 | 1.2.2.6.16 | TRANSPORTE DE MATERIAL PARA MONTAJE DE AULAS PREFABRICADAS DE MATERIAL TERMICO | 25d | 2023-02-18 | 2023-03-18 | 94SS | 586d |  | 11,866.3 | 01.02.06.16 |
| 96 | 1.2.3 | **SEGURIDAD EN OBRA Y PLAN PARA LA VIGILANCIA, PREVENCION Y CONTROL DE LA COVID-19** | 600d | 2023-02-01 | 2024-12-31 |  | 26d |  | 127,970.51 | 01.03 |
| 97 | 1.2.3.1 | **SEGURIDAD EN OBRA** | 600d | 2023-02-01 | 2024-12-31 |  | 26d |  | 14,373.76 | 01.03.01 |
| 98 | 1.2.3.1.1 | EQUIPO DE PROTECCION COLECCTIVA | 600d | 2023-02-01 | 2024-12-31 | 2SS | 26d | 0d | 2,999.4 | 01.03.01.01 |
| 99 | 1.2.3.1.2 | EQUIPO DE PROTECCION INDIVIDUAL | 600d | 2023-02-01 | 2024-12-31 | 98SS | 26d | 0d | 9,401.8 | 01.03.01.02 |
| 100 | 1.2.3.1.3 | SEÑALIZACION TEMPORAL EN OBRA | 600d | 2023-02-01 | 2024-12-31 | 99SS | 26d | 0d | 1,972.56 | 01.03.01.03 |
| 101 | 1.2.3.2 | **PLAN PARA LA PREVENCION Y CONTROL ANTE LA COVID-19 EN OBRA** | 600d | 2023-02-01 | 2024-12-31 |  | 26d |  | 113,596.75 | 01.03.02 |
| 102 | 1.2.3.2.1 | EQUIPO DE PROTECCION INDIVIDUAL PARA PERSONAL DE OBRA | 600d | 2023-02-01 | 2024-12-31 | 100SS | 26d | 0d | 14,437.2 | 01.03.02.01 |
| 103 | 1.2.3.2.2 | EQUIPO DE PROTECCION INDIVIDUAL PARA DIRECCION DE OBRA | 600d | 2023-02-01 | 2024-12-31 | 102SS | 26d | 0d | 23,897.04 | 01.03.02.02 |
| 104 | 1.2.3.2.3 | EQUIPO DE PROTECCION INDIVIDUAL PARA PERSONAL DE SALUD | 600d | 2023-02-01 | 2024-12-31 | 103SS | 26d | 0d | 8,379.12 | 01.03.02.03 |
| 105 | 1.2.3.2.4 | IDENTIFICACIÓN DE SINTOMATOLOGÍA COVID-19 PERIÓDICAMENTE AL INGRESO DE OBRA | 600d | 2023-02-01 | 2024-12-31 | 104SS | 26d | 0d | 52,676.16 | 01.03.02.04 |
| 106 | 1.2.3.2.5 | KIT PARA LAVADO Y DESINFECCION DE PERSONAL | 600d | 2023-02-01 | 2024-12-31 | 105SS | 26d | 0d | 7,604.88 | 01.03.02.05 |
| 107 | 1.2.3.2.6 | EQUIPAMIENTO PARA VIGILANCIA DE LA SALUD DEL TRABAJADOR | 600d | 2023-02-01 | 2024-12-31 | 106SS | 26d | 0d | 1,757.78 | 01.03.02.06 |
| 108 | 1.2.3.2.7 | EQUIPAMIENTO PARA DESINFECCIÓN DE ÁREAS COMUNES | 600d | 2023-02-01 | 2024-12-31 | 107SS | 26d | 0d | 2,210.85 | 01.03.02.07 |
| 109 | 1.2.3.2.8 | IMPLEMENTACION DE AREA DE TRIAJE (CONTROL PREVIO) | 2d | 2023-02-03 | 2023-02-04 | 108SS+2d | 622d |  | 2,633.72 | 01.03.02.08 |

| ID | WBS | Task | Duration | Start | Finish | Predecessors | Total slack | Free slack | Cost | Text1 |
| --- | --- | --- | --- | --- | --- | --- | --- | --- | --- | --- |
| 110 | 1.2.4 | **PLAN DE CONTINGENCIA** | 70d | 2023-02-10 | 2023-05-02 |  | 548d |  | 944,864.65 | 01.04 |
| 111 | 1.2.4.1 | TRAZO, NIVELACION Y REPLANTEO | 3d | 2023-02-10 | 2023-02-13 | 11SS+1d | 548d | 0d | 7,334.35 | 01.04.01 |
| 112 | 1.2.4.2 | CORTE DE TERRENO NATURAL CON MAQUINARIA | 4d | 2023-02-10 | 2023-02-14 | 111SS | 548d | 0d | 7,841 | 01.04.02 |
| 113 | 1.2.4.3 | CAPA DE MATERIAL DE PRESTAMO - HORMIGON e=0.15m CON EQUIPO PESADO | 3d | 2023-02-14 | 2023-02-16 | 112FS-1d | 548d | 0d | 49,747.31 | 01.04.03 |
| 114 | 1.2.4.4 | SUMINISTRO E INSTALACION DE PANELES DE TRIPLAY DE 1.20x2.40 DE 4mm | 22d | 2023-03-11 | 2023-04-05 | 116SS+2d | 548d | 0d | 165,814.57 | 01.04.04 |
| 115 | 1.2.4.5 | SUMINISTRO E INSTALACION DE PANELES DE FIBROCEMENTO TIPO ST DE 6mm | 22d | 2023-03-11 | 2023-04-05 | 114SS | 548d | 0d | 33,242.12 | 01.04.05 |
| 116 | 1.2.4.6 | SUMINISTRO E INSTALACION DE COLUMNAS DE MADERA DE 4" x 4" | 8d | 2023-03-09 | 2023-03-17 | 126FS-6d | 548d | 0d | 24,549.63 | 01.04.06 |
| 117 | 1.2.4.7 | SUMINISTRO E INSTALACION DE VIGAS DE MADERA DE 2" x 4" | 8d | 2023-03-30 | 2023-04-07 | 115FS-6d | 548d | 0d | 15,823.28 | 01.04.07 |
| 118 | 1.2.4.8 | PUERTAS DE TRIPLAY Y MARCO DE MADERA (1.00x2.10) INCL. CERROJO Y CANDADO | 8d | 2023-04-12 | 2023-04-20 | 123FS-5d | 548d | 0d | 18,900 | 01.04.08 |
| 119 | 1.2.4.9 | PUERTAS DE TRIPLAY Y MARCO DE MADERA (0.90x2.10) INCL. CERROJO Y CANDADO | 8d | 2023-04-12 | 2023-04-20 | 118SS | 548d | 0d | 3,040 | 01.04.09 |
| 120 | 1.2.4.10 | PUERTAS DE TRIPLAY Y MARCO DE MADERA (0.60x2.10) INCL. CERROJO Y CANDADO | 8d | 2023-04-12 | 2023-04-20 | 119SS | 548d | 0d | 4,480 | 01.04.10 |
| 121 | 1.2.4.11 | SUMINISTRO Y COLOCACION DE BISAGRA DE 4" EN PUERTAS | 8d | 2023-04-12 | 2023-04-20 | 120SS | 548d | 0d | 1,684.8 | 01.04.11 |
| 122 | 1.2.4.12 | SUMINISTRO Y COLOCACION DE VENTANAS INC. CELOCIA Y MARCO DE MADERA | 8d | 2023-04-12 | 2023-04-20 | 121SS | 548d | 0d | 45,463.76 | 01.04.12 |
| 123 | 1.2.4.13 | PLANCHAS DE PROLIPROPILENO DE e=1.2mm/COLOR ROJO - INCLUYE CORREAS DE MADERA 2" x 2" | 12d | 2023-04-04 | 2023-04-17 | 117FS-4d | 548d | 0d | 87,707.56 | 01.04.13 |
| 124 | 1.2.4.14 | LOSA DE CONCRETO F'C=140 KG/CM2, e=10cm/ACABADO FROTACHADO (INC. ENCOFRADO) | 15d | 2023-02-27 | 2023-03-15 | 189 | 548d | 0d | 196,628.58 | 01.04.14 |
| 125 | 1.2.4.15 | JUNTA ASFALTICA e=1" EN LOSA | 15d | 2023-02-27 | 2023-03-15 | 124SS | 548d | 0d | 2,987.75 | 01.04.15 |
| 126 | 1.2.4.16 | DADOS DE CONCRETO (0.35x0.35x0.50m) F'C=140 KG/CM2 | 15d | 2023-02-27 | 2023-03-15 | 125SS | 548d | 0d | 12,117.42 | 01.04.16 |
| 127 | 1.2.4.17 | SUMINISTRO Y COLOCACION DE PANEL CERCA PRO 2.40x3.00m, COLOR VERDE SEGUN DISEÑO INC. PARANTES METALICOS 3" x 3" x 3.00m | 18d | 2023-04-12 | 2023-05-02 | 122SS | 548d | 0d | 98,229.1 | 01.04.17 |
| 128 | 1.2.4.18 | SARDINEL (0.20x0.40) F'C=140 KG/CM2 | 18d | 2023-04-12 | 2023-05-02 | 127SS | 548d | 0d | 44,997.49 | 01.04.18 |
| 129 | 1.2.4.19 | SARDINEL (0.20x0.50 ) F'C=140 KG/CM2 | 18d | 2023-04-12 | 2023-05-02 | 128SS | 548d | 0d | 714.44 | 01.04.19 |
| 130 | 1.2.4.20 | TARRAJEO DE SARDINEL (0.20x0.50) | 18d | 2023-04-12 | 2023-05-02 | 129SS | 548d | 0d | 344.64 | 01.04.20 |
| 131 | 1.2.4.21 | PINTURA CON ESMALTE SINTETICO | 18d | 2023-04-12 | 2023-05-02 | 130SS | 548d | 0d | 32,827.67 | 01.04.21 |
| 132 | 1.2.4.22 | NIVELACION Y COLOCACION CONTRAPISO C:A PROP. 1:4 e=2" | 18d | 2023-04-12 | 2023-05-02 | 131SS | 548d | 0d | 18,311.7 | 01.04.22 |
| 133 | 1.2.4.23 | ACERO FY=4200 KG/CM2, EN CONTRAPISO PARA NIVELACION DE LOSA | 18d | 2023-04-12 | 2023-05-02 | 132SS | 548d | 0d | 8,566.4 | 01.04.23 |
| 134 | 1.2.4.24 | LAVADERO DE UNA POZA ACABADO PULIDO INC./INSTALACIONES | 18d | 2023-04-12 | 2023-05-02 | 133SS | 548d |  | 2,080 | 01.04.24 |
| 135 | 1.2.4.25 | ELIMINACION DE MATERIAL EXCEDENTE A 2.00 KM DE DISTANCIA DE LA OBRA | 2d | 2023-02-15 | 2023-02-16 | 112 | 612d |  | 61,431.08 | 01.04.25 |

| ID | WBS | Task | Duration | Start | Finish | Predecessors | Total slack | Free slack | Cost | Text1 |
| --- | --- | --- | --- | --- | --- | --- | --- | --- | --- | --- |
| 136 | 1.2.5 | **EVACUACION Y SEÑALIZACION** | 3d | 2023-04-21 | 2023-04-24 |  | 555d |  | 2,552.44 | 01.05 |
| 137 | 1.2.5.1 | SUMINISTRO Y COLOCACION DE SEÑALIZACION ADOSADA A PARED DE 0.20x0.30m | 2d | 2023-04-21 | 2023-04-22 | 122 | 555d | 0d | 1,646.4 | 01.05.01 |
| 138 | 1.2.5.2 | SUMINISTRO Y COLOCACION DE SEÑALIZACION ADOSADA A PARED DE 0.30x0.40m | 2d | 2023-04-21 | 2023-04-22 | 137SS | 555d | 0d | 100.08 | 01.05.02 |
| 139 | 1.2.5.3 | SUMINISTRO E INSTALACION DE EXTINTORES | 1d | 2023-04-24 | 2023-04-24 | 138 | 555d |  | 805.96 | 01.05.03 |
| 140 | 1.2.6 | **INSTALACIONES SANITARIAS** | 49d | 2023-02-17 | 2023-04-14 |  | 548d |  | 36,645.15 | 01.06 |
| 141 | 1.2.6.1 | **APARATOS SANITARIOS Y ACCESORIOS** | 3d | 2023-04-12 | 2023-04-14 |  | 563d |  | 17,377.84 | 01.06.01 |
| 142 | 1.2.6.1.1 | SUMINISTRO DE APARATOS SANITARIO (INODORO) | 3d | 2023-04-12 | 2023-04-14 | 121SS | 563d | 0d | 13,423.68 | 01.06.01.01 |
| 143 | 1.2.6.1.2 | SUMINISTRO DE ACCESORIOS P/INODOROS | 3d | 2023-04-12 | 2023-04-14 | 142SS | 563d | 0d | 1,023.36 | 01.06.01.02 |
| 144 | 1.2.6.1.3 | INSTALACION DE APARATOS SANITARIOS Y ACCESORIOS | 3d | 2023-04-12 | 2023-04-14 | 143SS | 563d |  | 2,930.8 | 01.06.01.03 |
| 145 | 1.2.6.2 | **SISTEMA DE AGUA FRIA** | 4d | 2023-02-17 | 2023-02-21 |  | 548d |  | 1,852.8 | 01.06.02 |
| 146 | 1.2.6.2.1 | **SALIDA DE AGUA FRIA** | 4d | 2023-02-17 | 2023-02-21 |  | 548d |  | 1,852.8 | 01.06.02.01 |
| 147 | 1.2.6.2.1.1 | SALIDA DE AGUA FRIA Ø 1/2" BRONCE | 4d | 2023-02-17 | 2023-02-21 | 113 | 548d | 0d | 1,852.8 | 01.06.02.01.01 |
| 148 | 1.2.6.3 | **REDES DE DISTRIBUCION** | 4d | 2023-02-17 | 2023-02-21 |  | 548d |  | 689.56 | 01.06.03 |
| 149 | 1.2.6.3.1 | TUBERIA PVC CLASE 10 SP P/AGUA FRIA D=3/4" | 4d | 2023-02-17 | 2023-02-21 | 147SS | 548d | 0d | 689.56 | 01.06.03.01 |
| 150 | 1.2.6.4 | **REDES DE ALIMENTACION** | 4d | 2023-02-17 | 2023-02-21 |  | 548d |  | 1,654.59 | 01.06.04 |
| 151 | 1.2.6.4.1 | TUBERIA PVC CLASE 10 SP P/AGUA FRIA D=1" | 4d | 2023-02-17 | 2023-02-21 | 149SS | 548d | 0d | 1,654.59 | 01.06.04.01 |
| 152 | 1.2.6.5 | **ACCESORIOS DE REDES DE AGUA** | 4d | 2023-02-17 | 2023-02-21 |  | 548d |  | 3,865.08 | 01.06.05 |
| 153 | 1.2.6.5.1 | **ACCESORIOS EN REDES DE DISTRIBUCION Y ALIMENTACION** | 4d | 2023-02-17 | 2023-02-21 |  | 548d |  | 3,865.08 | 01.06.05.01 |
| 154 | 1.2.6.5.1.1 | SUMINISTRO E INSTALACION DE CODO DE 90° PVC AGUA C-10 1" | 4d | 2023-02-17 | 2023-02-21 | 151SS | 548d | 0d | 64.98 | 01.06.05.01.01 |
| 155 | 1.2.6.5.1.2 | SUMINISTRO E INSTALACION DE CODO DE 90° PVC AGUA C-10 3/4" | 4d | 2023-02-17 | 2023-02-21 | 154SS | 548d | 0d | 562.8 | 01.06.05.01.02 |
| 156 | 1.2.6.5.1.3 | SUMINISTRO E INSTALACION DE TEE PVC SAP DE Ø 1" | 4d | 2023-02-17 | 2023-02-21 | 155SS | 548d | 0d | 59.94 | 01.06.05.01.03 |
| 157 | 1.2.6.5.1.4 | SUMINISTRO E INSTALACION DE TEE PVC AGUA C-10 3/4" | 4d | 2023-02-17 | 2023-02-21 | 156SS | 548d | 0d | 429.44 | 01.06.05.01.04 |
| 158 | 1.2.6.5.1.5 | SUMINISTRO E INSTALACION DE CODO DE BRONCE 1/2" | 4d | 2023-02-17 | 2023-02-21 | 157SS | 548d | 0d | 478.08 | 01.06.05.01.05 |
| 159 | 1.2.6.5.1.6 | SUMINISTRO E INSTALACION DE ADAPTADOR PVC AGUA C-10 3/4" | 4d | 2023-02-17 | 2023-02-21 | 158SS | 548d | 0d | 413.28 | 01.06.05.01.06 |
| 160 | 1.2.6.5.1.7 | SUMINISTRO E INSTALACION DE NIPLE PVC AGUA C-10 3/4" | 4d | 2023-02-17 | 2023-02-21 | 159SS | 548d | 0d | 155.52 | 01.06.05.01.07 |
| 161 | 1.2.6.5.1.8 | SUMINISTRO E INSTALACION DE REDUCCION PVC AGUA C-10 1" A 3/4" | 4d | 2023-02-17 | 2023-02-21 | 160SS | 548d | 0d | 42 | 01.06.05.01.08 |
| 162 | 1.2.6.5.1.9 | SUMINISTRO E INSTALACION DE REDUCCION PVC AGUA C-10 3/4 A 1/2" | 4d | 2023-02-17 | 2023-02-21 | 161SS | 548d | 0d | 429.12 | 01.06.05.01.09 |
| 163 | 1.2.6.5.1.10 | SUMINISTRO E INSTALACION DE TUBO DE ABASTO PARA INODORO | 4d | 2023-02-17 | 2023-02-21 | 162SS | 548d | 0d | 976.64 | 01.06.05.01.10 |
| 164 | 1.2.6.5.1.11 | SUMINISTRO E INSTALACION DE TRAMPA PLASTICA C/REGISTRO | 4d | 2023-02-17 | 2023-02-21 | 163SS | 548d | 0d | 122.08 | 01.06.05.01.11 |
| 165 | 1.2.6.5.1.12 | SUMINISTRO E INSTALACION DE UNION UNIVERSAL PVC 3/4" | 4d | 2023-02-17 | 2023-02-21 | 164SS | 548d | 0d | 131.2 | 01.06.05.01.12 |

| ID | WBS | Task | Duration | Start | Finish | Predecessors | Total slack | Free slack | Cost | Text1 |
| --- | --- | --- | --- | --- | --- | --- | --- | --- | --- | --- |
| 166 | 1.2.6.6 | **VALVULAS** | 4d | 2023-02-17 | 2023-02-21 |  | 548d |  | 343.88 | 01.06.06 |
| 167 | 1.2.6.6.1 | VALVULA COMPUERTA PESADA DE BRONCE DE 3/4" | 4d | 2023-02-17 | 2023-02-21 | 165SS | 548d | 0d | 343.88 | 01.06.06.01 |
| 168 | 1.2.6.7 | **ALMACENAMIENTO DE AGUA** | 4d | 2023-02-17 | 2023-02-21 |  | 548d |  | 2,300 | 01.06.07 |
| 169 | 1.2.6.7.1 | MANTENIMIENTO Y/O ADECUACION DE CISTERNA EXISTENTE | 4d | 2023-02-17 | 2023-02-21 | 167SS | 548d | 0d | 800 | 01.06.07.01 |
| 170 | 1.2.6.7.2 | MANTENIMIENTO Y/O ADECUACION DE CISTERNA | 4d | 2023-02-17 | 2023-02-21 | 169SS | 548d | 0d | 1,500 | 01.06.07.02 |
| 171 | 1.2.6.8 | **DESAGUE Y VENTILACION** | 4d | 2023-02-22 | 2023-02-25 |  | 548d |  | 2,034.64 | 01.06.08 |
| 172 | 1.2.6.8.1 | SALIDAS DE DESAGUE DE PVC 4" | 4d | 2023-02-22 | 2023-02-25 | 170 | 548d | 0d | 1,701.76 | 01.06.08.01 |
| 173 | 1.2.6.8.2 | SALIDAS DE DESAGUE DE PVC 2" | 4d | 2023-02-22 | 2023-02-25 | 172SS | 548d | 0d | 332.88 | 01.06.08.02 |
| 174 | 1.2.6.9 | **REDES DE DERIVACION** | 4d | 2023-02-22 | 2023-02-25 |  | 548d |  | 920.47 | 01.06.09 |
| 175 | 1.2.6.9.1 | TUBO DE DESAGUE DE PVC Ø 4" | 4d | 2023-02-22 | 2023-02-25 | 173SS | 548d | 0d | 764.83 | 01.06.09.01 |
| 176 | 1.2.6.9.2 | TUBO DE DESAGUE DE PVC Ø 2" | 4d | 2023-02-22 | 2023-02-25 | 175SS | 548d | 0d | 155.64 | 01.06.09.02 |
| 177 | 1.2.6.10 | **REDES COLECTORAS** | 4d | 2023-02-22 | 2023-02-25 |  | 548d |  | 2,306.87 | 01.06.10 |
| 178 | 1.2.6.10.1 | TUBERIA DE DESAGUE PVC SAP D= 4" | 4d | 2023-02-22 | 2023-02-25 | 176SS | 548d | 0d | 2,306.87 | 01.06.10.01 |
| 179 | 1.2.6.11 | **ACCESORIOS DE REDES DE DESAGUE** | 4d | 2023-02-22 | 2023-02-25 |  | 548d |  | 1,480.12 | 01.06.11 |
| 180 | 1.2.6.11.1 | SUMINISTRO E INSTALACION DE CODO 90° PVC Ø 4" | 4d | 2023-02-22 | 2023-02-25 | 178SS | 548d | 0d | 375.04 | 01.06.11.01 |
| 181 | 1.2.6.11.2 | SUMINISTRO E INSTALACION DE CODO 90° PVC Ø 2" | 4d | 2023-02-22 | 2023-02-25 | 180SS | 548d | 0d | 110.16 | 01.06.11.02 |
| 182 | 1.2.6.11.3 | SUMINISTRO E INSTALACION DE REGISTRO DE BRONCE 4" | 4d | 2023-02-22 | 2023-02-25 | 181SS | 548d | 0d | 56.2 | 01.06.11.03 |
| 183 | 1.2.6.11.4 | SUMINISTRO Y COLOCACION DE SUMIDERO CON TRAMPA P | 4d | 2023-02-22 | 2023-02-25 | 182SS | 548d | 0d | 104 | 01.06.11.04 |
| 184 | 1.2.6.11.5 | SUMINISTRO E INSTALACIÓN DE YEE DE 4" A 2" | 4d | 2023-02-22 | 2023-02-25 | 183SS | 548d | 0d | 65.32 | 01.06.11.05 |
| 185 | 1.2.6.11.6 | SUMINISTRO E INSTALACIÓN DE YEE SIMPLE 4" | 4d | 2023-02-22 | 2023-02-25 | 184SS | 548d | 0d | 509.12 | 01.06.11.06 |
| 186 | 1.2.6.11.7 | SUMINISTRO E INSTALACIÓN DE SOMBRERO DE VENTILACION 2" | 4d | 2023-02-22 | 2023-02-25 | 185SS | 548d | 0d | 173.52 | 01.06.11.07 |
| 187 | 1.2.6.11.8 | SUMINISTRO E INSTALACIÓN DE SOMBRERO DE VENTILACION 2" | 4d | 2023-02-22 | 2023-02-25 | 186SS | 548d | 0d | 86.76 | 01.06.11.08 |
| 188 | 1.2.6.12 | **CAMARAS DE INSPECCION** | 4d | 2023-02-22 | 2023-02-25 |  | 548d |  | 1,819.3 | 01.06.12 |
| 189 | 1.2.6.12.1 | SUMINISTRO E INSTALACION DE CAJA DE REGISTRO | 4d | 2023-02-22 | 2023-02-25 | 187SS | 548d | 0d | 1,819.3 | 01.06.12.01 |

| ID | WBS | Task | Duration | Start | Finish | Predecessors | Total slack | Free slack | Cost | Text1 |
| --- | --- | --- | --- | --- | --- | --- | --- | --- | --- | --- |
| 190 | 1.2.7 | **ELECTRICAS** | 8d | 2023-04-18 | 2023-04-26 |  | 553d |  | 18,468.08 | 01.07 |
| 191 | 1.2.7.1 | INSTALACIONES ELECTRIICAS EN AULAS PROVISIONALES | 8d | 2023-04-18 | 2023-04-26 | 123 | 553d |  | 18,468.08 | 01.07.01 |
| 192 | 1.3 | **ESTRUCTURAS** | 600d | 2023-02-01 | 2024-12-31 |  | 7d |  | 16,100,148.86 | 02 |
| 193 | 1.3.1 | **PLAN DE MANEJO AMBIENTAL** | 600d | 2023-02-01 | 2024-12-31 |  | 26d |  | 183,539.56 | 02.01 |
| 194 | 1.3.1.1 | PLAN DE MANEJO AMBIENTAL | 600d | 2023-02-01 | 2024-12-31 | 108SS | 26d |  | 183,539.56 | 02.01.01 |
| 195 | 1.3.2 | **MOVIMIENTO DE TIERRAS** | 438d | 2023-02-09 | 2024-07-03 |  | 0d |  | 1,432,318.98 | 02.02 |
| 196 | 1.3.2.1 | CORTE DE TERRENO NATURAL CON MAQUINARIA | 14d | 2023-02-09 | 2023-02-24 | 11SS | 0d |  | 23,646.5 | 02.02.01 |
| 197 | 1.3.2.2 | PERFILADO, NIVELACION Y COMPACTACION DE TERRENO NATURAL CON (MAQUINARIA) | 14d | 2023-02-09 | 2023-02-24 | 196SS | 0d |  | 78,762.96 | 02.02.02 |
| 198 | 1.3.2.3 | PERFILADO, NIVELACION Y COMPACTACION DE TERRENO NATURAL - MANUAL | 86d | 2023-02-14 | 2023-05-24 | 199SS | 529d |  | 45,669.52 | 02.02.03 |
| 199 | 1.3.2.4 | EXCAVACION MANUAL DE ZANJAS P/CIMIENTOS, ZAPATAS Y PISOS | 86d | 2023-02-14 | 2023-05-24 | 197FS-10d | 0d |  | 321,067.19 | 02.02.04 |
| 200 | 1.3.2.5 | MEJORAMIENTO CON MATERIAL DE PRESTAMO - ROCA MEDIANA DE 6" - 8" LLENAR VACIOS CON HORMIGON | 40d | 2023-04-20 | 2023-06-05 | 199FS-30d | 0d |  | 162,391.51 | 02.02.05 |
| 201 | 1.3.2.6 | COLOCACION, COMPACTACION Y NIVELACION DE CAPA DE HORMIGON (CON EQUIPO LIVIANO) | 25d | 2024-05-10 | 2024-06-07 | 249 | 23d | 0d | 177,357.29 | 02.02.06 |
| 202 | 1.3.2.7 | COLOCACION, COMPACTACION Y NIVELACION DE RELLENO CON MATERIAL PROPIO (CON EQUIPO LIVIANO) | 25d | 2023-09-28 | 2023-10-26 | 224 | 396d |  | 122,300.69 | 02.02.07 |
| 203 | 1.3.2.8 | COLOCACION, COMPACTACION Y NIVELACION DE CAPA DE AFIRMADO (CON EQUIPO LIVIANO) e=0.15m | 25d | 2024-05-16 | 2024-06-13 | 201FS-20d | 181d | 0d | 150,235.05 | 02.02.08 |
| 204 | 1.3.2.9 | CAPA DE MATERIAL DE PRESTAMO - HORMIGON GRUESO e=0.20m CON EQUIPO PESADO | 5d | 2024-06-21 | 2024-06-26 | 207 | 181d | 0d | 133,792.8 | 02.02.09 |
| 205 | 1.3.2.10 | COLCOACION, NIVELACION DE CAPA DE ARENA FINA e=0.05m, CON EQUIPO PESADO | 2d | 2024-06-29 | 2024-07-01 | 206 | 181d | 0d | 24,948 | 02.02.10 |
| 206 | 1.3.2.11 | COLCOACION , NIVELACION DE CAPA DE ARENA GRUESA e=0.05m, CON EQUIPO PESADO | 2d | 2024-06-27 | 2024-06-28 | 204 | 181d | 0d | 22,882.5 | 02.02.11 |
| 207 | 1.3.2.12 | COLCOACION, NIVELACION DE CAPA DE ARENA FINA e=0.05m, PARA PISO DE ADOQUIN | 12d | 2024-06-07 | 2024-06-20 | 203FS-6d | 181d | 0d | 8,171.62 | 02.02.12 |
| 208 | 1.3.2.13 | CAPA DE MATERIAL DE PRESTAMO - AFIRMADO e=0.20m CON EQUIPO PESADO | 2d | 2024-07-02 | 2024-07-03 | 205 | 181d |  | 42,402.56 | 02.02.13 |
| 209 | 1.3.2.14 | ELIMINACION DE MATERIAL EXCEDENTE A 2.00 KM DE DISTANCIA DE LA OBRA | 10d | 2023-05-25 | 2023-06-05 | 199 | 519d |  | 118,690.79 | 02.02.14 |
| 210 | 1.3.3 | **OBRAS DE CONCRETO SIMPLE** | 398d | 2023-05-25 | 2024-08-30 |  | 0d |  | 303,962.71 | 02.03 |
| 211 | 1.3.3.1 | FALSO PISO PROP 1:8 C:H | 20d | 2024-08-08 | 2024-08-30 | 303SS+10d | 131d |  | 56,751.22 | 02.03.01 |
| 212 | 1.3.3.2 | SOLADO PROP. 1:8, e=0.10m | 19d | 2023-05-25 | 2023-06-15 | 200FS-10d | 0d |  | 114,068.15 | 02.03.02 |
| 213 | 1.3.3.3 | CIMIENTO DE CONCRETO CICLOPEO PROP. 1:8 + 25% P.M. | 2d | 2023-08-22 | 2023-08-23 | 220SS+2d | 431d | 0d | 7,069.86 | 02.03.03 |
| 214 | 1.3.3.4 | CIMIENTO DE CONCRETO CICLOPEO PROP. 1:10 + 30% P.G. | 20d | 2023-08-24 | 2023-09-15 | 213 | 431d |  | 126,073.48 | 02.03.04 |

| ID | WBS | Task | Duration | Start | Finish | Predecessors | Total slack | Cost | Text1 |
| --- | --- | --- | --- | --- | --- | --- | --- | --- | --- |
| 215 | 1.3.4 | **OBRAS DE CONCRETO ARMADO** | 383d | 2023-06-05 | 2024-08-23 |  | 0d | 13,154,730.43 | 02.04 |
| 216 | 1.3.4.1 | **ZAPATAS** | 55d | 2023-06-05 | 2023-08-07 |  | 0d | 1,617,936.51 | 02.04.01 |
| 217 | 1.3.4.1.1 | CONCRETO F'C=280 KG/CM2 - PARA ZAPATAS | 30d | 2023-07-04 | 2023-08-07 | 218FS-20d | 0d | 698,160.95 | 02.04.01.01 |
| 218 | 1.3.4.1.2 | ACERO CORRUGADO FY=4200 KG/CM2 GRADO 60 - PARA ZAPATAS | 45d | 2023-06-05 | 2023-07-26 | 212FS-10d | 0d | 919,775.56 | 02.04.01.02 |
| 219 | 1.3.4.2 | **VIGA DE CIMENTACION** | 33d | 2023-07-21 | 2023-08-28 |  | 0d | 293,034.49 | 02.04.02 |
| 220 | 1.3.4.2.1 | CONCRETO F'C=280 KG/CM2 - EN VIGAS DE CIMENTACION | 8d | 2023-08-19 | 2023-08-28 | 222FS-4d | 0d | 74,165.37 | 02.04.02.01 |
| 221 | 1.3.4.2.2 | ACERO CORRUGADO FY=4200 KG/CM2 GRADO 60 - VIGA DE CIMENTACION | 22d | 2023-07-21 | 2023-08-15 | 217FS-15d | 0d | 172,621.71 | 02.04.02.02 |
| 222 | 1.3.4.2.3 | ENCOFRADO Y DESENCOFRADO DE VIGA DE CIMENTACION | 22d | 2023-07-29 | 2023-08-23 | 221FS-15d | 0d | 46,247.41 | 02.04.02.03 |
| 223 | 1.3.4.3 | **SOBRECIMIENTO ARMADO** | 32d | 2023-08-22 | 2023-09-27 |  | 0d | 427,550.06 | 02.04.03 |
| 224 | 1.3.4.3.1 | CONCRETO F'C=175 KG/CM2 - PARA SOBRECIMIENTO ARMADO | 12d | 2023-09-14 | 2023-09-27 | 226FS-8d | 0d | 122,274.56 | 02.04.03.01 |
| 225 | 1.3.4.3.2 | ACERO CORRUGADO FY=4200 KG/CM2 GRADO 60 - PARA SOBRECIMIENTO ARMADO | 24d | 2023-08-22 | 2023-09-18 | 220SS+2d | 0d | 113,377.3 | 02.04.03.02 |
| 226 | 1.3.4.3.3 | ENCOFRADO Y DESENCOFRADO DE SOBRECIMIENTO | 24d | 2023-08-26 | 2023-09-22 | 225FS-20d | 0d | 191,898.2 | 02.04.03.03 |
| 227 | 1.3.4.4 | **COLUMNAS Y PLACAS** | 115d | 2023-09-14 | 2024-01-25 |  | 0d | 4,620,064.69 | 02.04.04 |
| 228 | 1.3.4.4.1 | CONCRETO F'C=210 KG/CM2 PARA COLUMNAS | 40d | 2023-12-11 | 2024-01-25 | 230FS-30d | 0d | 1,068,127.01 | 02.04.04.01 |
| 229 | 1.3.4.4.2 | ACERO CORRUGADO FY=4200 KG/CM2 GRADO 60 PARA COLUMNA Y PLACAS | 85d | 2023-09-14 | 2023-12-21 | 224SS | 0d | 2,265,631.22 | 02.04.04.02 |
| 230 | 1.3.4.4.3 | ENCOFRADO Y DESENCOFRADO DE COLUMNA Y PLACAS | 90d | 2023-10-02 | 2024-01-13 | 229FS-70d | 0d | 1,286,306.46 | 02.04.04.03 |
| 231 | 1.3.4.5 | **COLUMNETAS** | 43d | 2024-05-28 | 2024-07-16 |  | 0d | 645,351.12 | 02.04.05 |
| 232 | 1.3.4.5.1 | CONCRETO F'C=175 KG/CM2 EN COLUMNETAS | 18d | 2024-06-26 | 2024-07-16 | 234FS-5d | 0d | 95,026.75 | 02.04.05.01 |
| 233 | 1.3.4.5.2 | ACERO CORRUGADO FY=4200 KG/CM2 GRADO 60 - PARA COLUMNETAS | 30d | 2024-05-28 | 2024-07-01 | 284FS-20d | 0d | 372,752.36 | 02.04.05.02 |
| 234 | 1.3.4.5.3 | ENCOFRADO Y DESENCOFRADO DE COLUMNETAS | 30d | 2024-05-28 | 2024-07-01 | 233SS | 0d | 177,572.01 | 02.04.05.03 |
| 235 | 1.3.4.6 | **VIGAS** | 120d | 2023-12-22 | 2024-05-09 |  | 0d | 2,646,638.18 | 02.04.06 |
| 236 | 1.3.4.6.1 | CONCRETO F'C= 210 KG/CM2 EN VIGAS | 60d | 2024-03-01 | 2024-05-09 | 245FS-50d | 0d | 630,483.45 | 02.04.06.01 |
| 237 | 1.3.4.6.2 | ACERO CORRUGADO FY=4200 KG/CM2 GRADO 60 - PARA VIGAS | 110d | 2023-12-22 | 2024-04-27 | 247SS | 0d | 1,315,643.23 | 02.04.06.02 |
| 238 | 1.3.4.6.3 | ENCOFRADO Y DESENCOFRADO DE VIGAS | 110d | 2023-12-22 | 2024-04-27 | 228FS-30d | 0d | 700,511.5 | 02.04.06.03 |

| ID | WBS | Task | Duration | Start | Finish | Predecessors | Total slack | Free slack | Cost | Text1 |
| --- | --- | --- | --- | --- | --- | --- | --- | --- | --- | --- |
| 239 | 1.3.4.7 | **VIGAS DE CIERRE EN MUROS** | 38d | 2024-06-29 | 2024-08-12 |  | 0d |  | 439,137.85 | 02.04.07 |
| 240 | 1.3.4.7.1 | CONCRETO F'C= 175KG/CM2 EN VIGAS DE CIERRE | 16d | 2024-07-25 | 2024-08-12 | 242FS-8d | 0d |  | 83,271.62 | 02.04.07.01 |
| 241 | 1.3.4.7.2 | ACERO CORRUGADO FY=4200 KG/CM2 GRADO 60 - VIGA DE CIERRE | 30d | 2024-07-05 | 2024-08-08 | 232FS-10d | 0d |  | 189,994.29 | 02.04.07.02 |
| 242 | 1.3.4.7.3 | ENCOFRADO Y DESENCOFRADO DE VIGAS DE CIERRE | 30d | 2024-06-29 | 2024-08-02 | 241FS-35d | 0d |  | 165,871.94 | 02.04.07.03 |
| 243 | 1.3.4.8 | **LOSA ALIGERADA** | 120d | 2023-12-22 | 2024-05-09 |  | 0d |  | 1,744,077.9 | 02.04.08 |
| 244 | 1.3.4.8.1 | CONCRETO F'C=210 KG/CM2 EN LOSA ALIGERADA | 60d | 2024-03-01 | 2024-05-09 | 236SS | 0d |  | 338,733.64 | 02.04.08.01 |
| 245 | 1.3.4.8.2 | ACERO CORRUGADO FY=4200 KG/CM2 GRADO 60 - PARA LOSAS ALIGERADAS | 110d | 2023-12-22 | 2024-04-27 | 237SS | 0d |  | 386,251.46 | 02.04.08.02 |
| 246 | 1.3.4.8.3 | ENCOFRADO Y DESENCOFRADO DE LOSA ALIGERADA | 110d | 2023-12-22 | 2024-04-27 | 238SS | 0d |  | 707,409.09 | 02.04.08.03 |
| 247 | 1.3.4.8.4 | LADRILLO DE TECHO 15x30x30 - LOSA ALIGERADA | 110d | 2023-12-22 | 2024-04-27 | 246SS | 0d |  | 311,683.71 | 02.04.08.04 |
| 248 | 1.3.4.9 | **LOSA MACIZA** | 120d | 2023-12-22 | 2024-05-09 |  | 60d |  | 251,780.08 | 02.04.09 |
| 249 | 1.3.4.9.1 | CONCRETO F'C=210 KG/CM2 PARA LOSA MACIZA | 60d | 2024-03-01 | 2024-05-09 | 244SS | 0d |  | 55,423.67 | 02.04.09.01 |
| 250 | 1.3.4.9.2 | ACERO CORRUGADO FY=4200 KG/CM2 GRADO 60 - LOSA MACIZA | 110d | 2023-12-22 | 2024-04-27 | 245SS | 238d |  | 126,940.09 | 02.04.09.02 |
| 251 | 1.3.4.9.3 | ENCOFRADO Y DESENCOFRADO DE LOSA MACIZA | 110d | 2023-12-22 | 2024-04-27 | 246SS | 238d |  | 69,416.32 | 02.04.09.03 |
| 252 | 1.3.4.10 | **ESCALERA** | 32d | 2024-05-10 | 2024-06-15 |  | 122d |  | 154,881.37 | 02.04.10 |
| 253 | 1.3.4.10.1 | CONCRETO F'C=210 KG/CM2 EN ESCALERA | 7d | 2024-06-08 | 2024-06-15 | 254 | 122d | 0d | 46,444.29 | 02.04.10.01 |
| 254 | 1.3.4.10.2 | ACERO DE REFUERZO F'Y=4,200 KG/CM2 GRADO 60 PARA ESCALERA | 15d | 2024-05-22 | 2024-06-07 | 255FS-10d | 122d | 0d | 57,356.69 | 02.04.10.02 |
| 255 | 1.3.4.10.3 | ENCOFRADO Y DESENCOFRADO DE ESCALERA | 20d | 2024-05-10 | 2024-06-01 | 269SS+5d | 122d | 0d | 51,080.39 | 02.04.10.03 |
| 256 | 1.3.4.11 | **RAMPA** | 22d | 2024-06-14 | 2024-07-09 |  | 122d |  | 69,452.45 | 02.04.11 |
| 257 | 1.3.4.11.1 | CONCRETO F'C=210 KG/CM2 EN RAMPA | 4d | 2024-07-05 | 2024-07-09 | 259 | 122d | 0d | 20,035.43 | 02.04.11.01 |
| 258 | 1.3.4.11.2 | ACERO CORRUGADO FY=4200 KG/CM2 GRADO 60 - PARA RAMPA | 12d | 2024-06-14 | 2024-06-27 | 253FS-2d | 122d | 0d | 33,184.23 | 02.04.11.02 |
| 259 | 1.3.4.11.3 | ENCOFRADO Y DESENCOFRADO DE RAMPA | 12d | 2024-06-21 | 2024-07-04 | 258FS-6d | 122d | 0d | 16,232.79 | 02.04.11.03 |
| 260 | 1.3.4.12 | **GRADERIAS EN TRIBUNAS** | 29d | 2024-07-05 | 2024-08-07 |  | 122d |  | 120,486.43 | 02.04.12 |
| 261 | 1.3.4.12.1 | CONCRETO F'C=210 KG/CM2 EN GRADERIAS DE TRIBUNAS | 6d | 2024-08-01 | 2024-08-07 | 263FS-4d | 122d | 0d | 25,528.85 | 02.04.12.01 |
| 262 | 1.3.4.12.2 | ACERO CORRUGADO FY=4200 KG/CM2 GRADO 60 - EN GRADERIAS DE TRIBUNAS | 25d | 2024-07-05 | 2024-08-02 | 257SS | 122d | 0d | 70,257.43 | 02.04.12.02 |
| 263 | 1.3.4.12.3 | ENCOFRADO Y DESENCOFRADO EN GRADERIAS DE TRIBUNAS | 25d | 2024-07-08 | 2024-08-05 | 262SS+2d | 122d | 0d | 24,700.15 | 02.04.12.03 |

| ID | WBS | Task | Duration | Start | Finish | Predecessors | Total slack | Free slack | Cost | Text1 |
| --- | --- | --- | --- | --- | --- | --- | --- | --- | --- | --- |
| 264 | 1.3.4.13 | **CISTERNA** | 14d | 2024-08-08 | 2024-08-23 |  | 122d |  | 124,339.3 | 02.04.13 |
| 265 | 1.3.4.13.1 | CONCRETO F'C=210 KG/CM2 EN CISTERNA | 2d | 2024-08-22 | 2024-08-23 | 267 | 122d | 0d | 35,362.51 | 02.04.13.01 |
| 266 | 1.3.4.13.2 | ACERO CORRUGADO FY=4200 KG/CM2 GRADO 60 - PARA CISTERNA | 6d | 2024-08-08 | 2024-08-14 | 261 | 122d | 0d | 70,257.43 | 02.04.13.02 |
| 267 | 1.3.4.13.3 | ENCOFRADO Y DESENCOFRADO PARA CISTERNA | 6d | 2024-08-15 | 2024-08-21 | 266 | 122d | 0d | 18,719.36 | 02.04.13.03 |
| 268 | 1.3.5 | **COBERTURAS LIVIANAS** | 40d | 2024-05-04 | 2024-06-19 |  | 0d |  | 801,640.16 | 02.05 |
| 269 | 1.3.5.1 | SUMINISTRO Y COLOCACION DE TIJERAL METALICO CURVO TIPO 1 LONG=27.80M | 40d | 2024-05-04 | 2024-06-19 | 292FS-40d | 0d |  | 98,338.8 | 02.05.01 |
| 270 | 1.3.5.2 | SUMINISTRO Y COLOCACION DE TIJERAL METALICO TRIANGULAR TIPO 2 LONG=7.95M | 40d | 2024-05-04 | 2024-06-19 | 269SS | 0d |  | 48,135.12 | 02.05.02 |
| 271 | 1.3.5.3 | SUMINISTRO Y COLOCACION DE VIGUETA METALICA TIPO VG-C | 40d | 2024-05-04 | 2024-06-19 | 270SS | 0d |  | 255,103.53 | 02.05.03 |
| 272 | 1.3.5.4 | SUMINISTRO Y COLOCACION DE VIGUETA METALICA TUB. RECT. 2" x3" x 2.00mm | 40d | 2024-05-04 | 2024-06-19 | 271SS | 0d |  | 34,828.92 | 02.05.04 |
| 273 | 1.3.5.5 | SUMINISTRO Y COLOCACION DE TEMPLADOR DE Ø 5/8" | 40d | 2024-05-04 | 2024-06-19 | 272SS | 0d |  | 10,624.8 | 02.05.05 |
| 274 | 1.3.5.6 | SUMINISTRO Y COLOCACION DE TEMPLADOR DE Ø 3/8" | 40d | 2024-05-04 | 2024-06-19 | 273SS | 0d |  | 4,197.25 | 02.05.06 |
| 275 | 1.3.5.7 | SUMINISTRO Y COLOCACION DE TENSORES DE FIERRO LISO Ø 1" | 40d | 2024-05-04 | 2024-06-19 | 274SS | 0d |  | 11,397 | 02.05.07 |
| 276 | 1.3.5.8 | SUMINISTRO Y COLOCACION DE TENSORES DE FIERRO LISO Ø 3/4" | 40d | 2024-05-04 | 2024-06-19 | 275SS | 0d |  | 2,877.34 | 02.05.08 |
| 277 | 1.3.5.9 | SUMINISTRO Y COLOCACION DE COLGANTE DE FIERRO LISO Ø 1/2" | 40d | 2024-05-04 | 2024-06-19 | 276SS | 0d |  | 3,004.2 | 02.05.09 |
| 278 | 1.3.5.10 | SUMINISTRO Y COLOCACION DE COBERTURA DE ACERO ALUMINIZADO (CALAMINON CU e=0.50m) | 40d | 2024-05-04 | 2024-06-19 | 277SS | 0d |  | 247,054.08 | 02.05.10 |
| 279 | 1.3.5.11 | SUMINISTRO Y COLOCACION DE COBERTURA DE ACERO ALUMINIZADO (CALAMINON TI e=0.40m) | 40d | 2024-05-04 | 2024-06-19 | 278SS | 0d |  | 33,696.27 | 02.05.11 |
| 280 | 1.3.5.12 | SUMINISTRO Y COLOCACION DE APOYOS FIJOS ENTRE COLUMNA Y TIJERAL PARABOLICO | 40d | 2024-05-04 | 2024-06-19 | 279SS | 0d |  | 4,332.36 | 02.05.12 |
| 281 | 1.3.5.13 | SUMINISTRO Y COLOCACION DE APOYOS MOVIL ENTRE COLUMNA Y TIJERAL PARABOLICO | 40d | 2024-05-04 | 2024-06-19 | 280SS | 0d |  | 5,866.44 | 02.05.13 |
| 282 | 1.3.5.14 | SUMINISTRO Y COLOCACION DE ARRIOSTRE DE FIERRO CORRUGADO Ø 3/8" | 40d | 2024-05-04 | 2024-06-19 | 281SS | 0d |  | 18,580.8 | 02.05.14 |
| 283 | 1.3.5.15 | SUMINISTRO Y COLOCACION DE CANALETA DE PLANCHA GALVANIZADA 2mm (0.10x0.20x0.15m) | 40d | 2024-05-04 | 2024-06-19 | 282SS | 0d |  | 20,747.57 | 02.05.15 |
| 284 | 1.3.5.16 | SUMINISTRO Y COLOCACION DE BAJADA DE MONTANTE DE TUBERIA PVC Ø 3" | 40d | 2024-05-04 | 2024-06-19 | 283SS | 0d |  | 2,855.68 | 02.05.16 |
| 285 | 1.3.6 | **OTROS** | 380d | 2023-07-21 | 2024-10-05 |  | 100d |  | 223,957.02 | 02.06 |
| 286 | 1.3.6.1 | JUNTAS DE DILATACION ASFALTICA e=1" EN CERCO PERIMETRICO | 4d | 2024-09-06 | 2024-09-10 | 287 | 122d |  | 5,956.29 | 02.06.01 |
| 287 | 1.3.6.2 | TARRAJEO DE CISTERNA Y TANQUE ELEVADO PROP. 1:4, e=1.50cm, CON ADITIVO IMPERMEABILIZANTE | 8d | 2024-08-28 | 2024-09-05 | 265SS+5d | 122d | 0d | 12,007.92 | 02.06.02 |
| 288 | 1.3.6.3 | CURADO DE ESTRUCTURAS DE CONCRETO CON ADITIVO | 380d | 2023-07-21 | 2024-10-05 | 219SS | 100d |  | 205,453.61 | 02.06.03 |
| 289 | 1.3.6.4 | COLOCACION DE CINTA WATER STOP 6" - CAUCHO NATURAL | 1d | 2024-08-22 | 2024-08-22 | 265SS | 138d |  | 539.2 | 02.06.04 |

| ID | WBS | Task | Duration | Start | Finish | Predecessors | Total slack | Free slack | Cost | Text1 |
| --- | --- | --- | --- | --- | --- | --- | --- | --- | --- | --- |
| 290 | 1.4 | **ARQUITECTURA** | 358d | 2023-12-11 | 2025-01-30 |  | 0d |  | 8,603,495.2 | 03 |
| 291 | 1.4.1 | **MUROS Y TABIQUES** | 75d | 2024-03-25 | 2024-06-19 |  | 0d |  | 835,388.52 | 03.01 |
| 292 | 1.4.1.1 | MURO DE LADRILLO TIPO IV (12.5x9x23) APAREJO DE SOGA | 75d | 2024-03-25 | 2024-06-19 | 249FS-40d | 0d |  | 831,171.58 | 03.01.01 |
| 293 | 1.4.1.2 | MURO DE LADRILLO TIPO IV (12.5x9x23) APAREJO DE CABEZA | 75d | 2024-03-25 | 2024-06-19 | 292SS | 193d |  | 4,216.94 | 03.01.02 |
| 294 | 1.4.2 | **REVOQUES Y ENLUCIDOS** | 60d | 2024-07-27 | 2024-10-04 |  | 0d |  | 2,330,817.86 | 03.02 |
| 295 | 1.4.2.1 | TARRAJEO EN MUROS EXTERIORES CA 1:4, e=1.5cm, CEMENTO TIPO ICO | 60d | 2024-07-27 | 2024-10-04 | 240SS+2d | 0d |  | 473,124.48 | 03.02.01 |
| 296 | 1.4.2.2 | TARRAJEO EN MUROS INTERIORES CA 1:4, e=1.5cm, CEMENTO TIPO ICO | 60d | 2024-07-27 | 2024-10-04 | 295SS | 0d |  | 179,218.64 | 03.02.02 |
| 297 | 1.4.2.3 | TARRAJEO EN COLUMNAS PROP. 1:5 e=1.5cm, CEMENTO TIPO ICO | 60d | 2024-07-27 | 2024-10-04 | 296SS | 0d |  | 625,734.71 | 03.02.03 |
| 298 | 1.4.2.4 | TARRAJEO EN CIELO RASO PROP. 1:5, e=1.5cm, CEMENTO TIPO ICO | 60d | 2024-07-27 | 2024-10-04 | 297SS | 0d |  | 608,866.59 | 03.02.04 |
| 299 | 1.4.2.5 | TARRAJEO DE VIGAS PROP. 1:4, e=1.5cm, CEMENTO TIPO ICO | 60d | 2024-07-27 | 2024-10-04 | 298SS | 0d |  | 325,627.39 | 03.02.05 |
| 300 | 1.4.2.6 | TARRAJEO DE RAYADO PRIMARIO MEZCLA 1:4 | 60d | 2024-07-27 | 2024-10-04 | 299SS | 0d |  | 33,287.87 | 03.02.06 |
| 301 | 1.4.2.7 | TARRAJEO DE SOBRECIMIENTO PROP. 1:4 e=1.5cm CEMENTO TIPO ICO | 60d | 2024-07-27 | 2024-10-04 | 300SS | 0d |  | 11,917.41 | 03.02.07 |
| 302 | 1.4.2.8 | REVESTIMIENTO DE DERRAMES h=0.15m, PROP. 1:4, e=1.5cm, CEMENTO TIPO ICO | 60d | 2024-07-27 | 2024-10-04 | 301SS | 0d |  | 39,049.95 | 03.02.08 |
| 303 | 1.4.2.9 | TARRAJEO DE GRADERIAS ACABADO SEMI-PULIDO e=1.5cm CEMENTO TIPO ICO INC. BRUÑADO | 60d | 2024-07-27 | 2024-10-04 | 302SS | 0d |  | 33,990.82 | 03.02.09 |
| 304 | 1.4.3 | **PINTURA** | 45d | 2024-11-01 | 2024-12-23 |  | 0d |  | 802,034.81 | 03.03 |
| 305 | 1.4.3.1 | PINTURA LATEX SATINADA EN MUROS EXTERIORES | 45d | 2024-11-01 | 2024-12-23 | 388FS-22d | 0d |  | 171,034.05 | 03.03.01 |
| 306 | 1.4.3.2 | PINTURA LATEX SATINADA EN MUROS INTERIORES | 45d | 2024-11-01 | 2024-12-23 | 305SS | 19d | 0d | 83,332.16 | 03.03.02 |
| 307 | 1.4.3.3 | PINTURA LATEX SATINADA EN COLUMNAS | 45d | 2024-11-01 | 2024-12-23 | 306SS | 19d | 0d | 217,880 | 03.03.03 |
| 308 | 1.4.3.4 | PINTURA LATEX SATINADA EN CIELO RASO | 45d | 2024-11-01 | 2024-12-23 | 307SS | 19d | 0d | 179,894.92 | 03.03.04 |
| 309 | 1.4.3.5 | PINTURA LATEX SATINADA EN VIGAS | 45d | 2024-11-01 | 2024-12-23 | 308SS | 19d | 0d | 118,933 | 03.03.05 |
| 310 | 1.4.3.6 | PINTURA LATEX SATINADA EN DERRAMES | 45d | 2024-11-01 | 2024-12-23 | 309SS | 19d | 0d | 8,092.53 | 03.03.06 |
| 311 | 1.4.3.7 | PINTURA ESMALTE SINTETICO a=5cm | 45d | 2024-11-01 | 2024-12-23 | 310SS | 19d | 0d | 1,755.55 | 03.03.07 |
| 312 | 1.4.3.8 | PINTURA ESMALTE EN CONTRAZOCALO DE CEMENTO h=0.30m | 45d | 2024-11-01 | 2024-12-23 | 311SS | 19d | 0d | 7,083.9 | 03.03.08 |
| 313 | 1.4.3.9 | PINTURA ESMALTE EN CONTRAZOCALO DE CEMENTO h=0.10m | 45d | 2024-11-01 | 2024-12-23 | 312SS | 19d | 0d | 8,383.03 | 03.03.09 |
| 314 | 1.4.3.10 | PINTURA ESMALTE EN CONTRA PASO DE TRIBUNA h=0.40m | 45d | 2024-11-01 | 2024-12-23 | 313SS | 19d | 0d | 5,645.67 | 03.03.10 |

| ID | WBS | Task | Duration | Start | Finish | Predecessors | Total slack | Cost | Text1 |
| --- | --- | --- | --- | --- | --- | --- | --- | --- | --- |
| 315 | 1.4.4 | **PISOS Y PAVIMENTOS** | 65d | 2024-08-20 | 2024-11-02 |  | 0d | 1,495,472.94 | 03.04 |
| 316 | 1.4.4.1 | CONTRAPISO C:A PROP. 1:4, e=2.5cm | 20d | 2024-08-20 | 2024-09-11 | 303FS-40d | 0d | 189,018.35 | 03.04.01 |
| 317 | 1.4.4.2 | PISO CERAMICO 0.30 x 0.30 ANTIDESLIZANTE, ALTO TRANSITO | 60d | 2024-08-26 | 2024-11-02 | 316SS+5d | 0d | 316,564.16 | 03.04.02 |
| 318 | 1.4.4.3 | ENCHAPE CERAMICO (0.30x0.30) | 60d | 2024-08-26 | 2024-11-02 | 317SS | 0d | 11,070.48 | 03.04.03 |
| 319 | 1.4.4.4 | CONCRETO EN VEREDAS F'C=175 KG/CM2, e=10cm, ACABADO FROTACHADO FINO Y BRUÑADO | 60d | 2024-08-26 | 2024-11-02 | 318SS | 0d | 189,981.05 | 03.04.04 |
| 320 | 1.4.4.5 | PISO CEMENTO FROTACHADO FINO Y BRUÑADO | 60d | 2024-08-26 | 2024-11-02 | 319SS | 0d | 133,780.54 | 03.04.05 |
| 321 | 1.4.4.6 | PISO DE ADOQUIN DE CONCRETO h=4cm | 60d | 2024-08-26 | 2024-11-02 | 320SS | 0d | 71,226.76 | 03.04.06 |
| 322 | 1.4.4.7 | LOSA DEPORTIVA DE C° F'C=175 KG/CM2, e=0.15m INC. ENCOFRADO Y DESENCOFRADO | 60d | 2024-08-26 | 2024-11-02 | 321SS | 0d | 296,845.91 | 03.04.07 |
| 323 | 1.4.4.8 | CONCRETO EN LOSAS F'C=210 KG/CM2, e=20cm INCLUYE ENCOFRADO Y DESENCOFRADO | 60d | 2024-08-26 | 2024-11-02 | 322SS | 0d | 41,837.39 | 03.04.08 |
| 324 | 1.4.4.9 | CORTE EN FALSO PISO | 60d | 2024-08-26 | 2024-11-02 | 323SS | 0d | 903.38 | 03.04.09 |
| 325 | 1.4.4.10 | CORTE EN CONTRAPISO | 60d | 2024-08-26 | 2024-11-02 | 324SS | 0d | 644.92 | 03.04.10 |
| 326 | 1.4.4.11 | SUMINISTRO E INSTALACION DE PISO DE POLIURETANO | 60d | 2024-08-26 | 2024-11-02 | 325SS | 0d | 243,600 | 03.04.11 |
| 327 | 1.4.5 | **ZOCALOS Y CONTRAZOCALOS** | 60d | 2024-08-26 | 2024-11-02 |  | 0d | 150,311.25 | 03.05 |
| 328 | 1.4.5.1 | ZOCALO DE CERAMICO 0.30 x 0.30m | 60d | 2024-08-26 | 2024-11-02 | 326SS | 0d | 67,437.41 | 03.05.01 |
| 329 | 1.4.5.2 | CONTRA ZOCALO DE CERAMICA e=0.10m | 60d | 2024-08-26 | 2024-11-02 | 328SS | 0d | 27,278.51 | 03.05.02 |
| 330 | 1.4.5.3 | CONTRA ZOCALO DE CEMENTO H= 0.30m e=1.5cm | 60d | 2024-08-26 | 2024-11-02 | 329SS | 0d | 17,053.1 | 03.05.03 |
| 331 | 1.4.5.4 | CONTRA ZOCALO DE CEMENTO H= 0.10m e=1.5cm | 60d | 2024-08-26 | 2024-11-02 | 330SS | 0d | 38,542.23 | 03.05.04 |
| 332 | 1.4.6 | **CARPINTERIA DE MADERA** | 30d | 2024-10-11 | 2024-11-14 |  | 0d | 432,275.89 | 03.06 |
| 333 | 1.4.6.1 | SUMINISTRO Y COLOCACION DE PUERTAS DE MADERA CEDRO MACHIEMMBRADA (1.00X2.10M) CON VISOR DE VIDRIO E=6MM, CON LAMINA DE SEGURIDAD Y CERRAJERIA | 30d | 2024-10-11 | 2024-11-14 | 331FS-20d | 0d | 119,250 | 03.06.01 |
| 334 | 1.4.6.2 | SUMINISTRO Y COLOCACION DE PUERTAS DE MADERA CEDRO MACHIEMMBRADA (1.80X2.10M) CON VISOR DE VIDRIO E=6MM, CON LAMINA DE SEGURIDAD Y CERRAJERIA | 30d | 2024-10-11 | 2024-11-14 | 333SS | 0d | 73,150 | 03.06.02 |
| 335 | 1.4.6.3 | SUMINISTRO Y COLOCACION DE PUERTAS DE MADERA CEDRO MACHIEMMBRADA (0.90X2.10M) CON CERRAJERIA | 30d | 2024-10-11 | 2024-11-14 | 334SS | 0d | 60,000 | 03.06.03 |
| 336 | 1.4.6.4 | SUMINISTRO Y COLOCACION DE PUERTAS DE MADERA CEDRO MACHIEMMBRADA (0.80X2.10M) CON CERRAJERIA | 30d | 2024-10-11 | 2024-11-14 | 335SS | 0d | 7,200 | 03.06.04 |
| 337 | 1.4.6.5 | SUMINISTRO Y COLOCACION DE PUERTAS DE MADERA CEDRO MACHIEMMBRADA (1.00X2.10) CON FRESQUILLO H=1.10M Y CERRAJERIA | 30d | 2024-10-11 | 2024-11-14 | 336SS | 0d | 9,975 | 03.06.05 |
| 338 | 1.4.6.6 | SUMINISTRO Y COLOCACION DE PUERTAS DE MADERA CEDRO MACHIEMMBRADA (1.20X2.10) CON FRESQUILLO H=1.10M Y CERRAJERIA | 30d | 2024-10-11 | 2024-11-14 | 337SS | 0d | 16,100 | 03.06.06 |
| 339 | 1.4.6.7 | SUMINISTRO Y COLOCACION DE PUERTAS DE MADERA CEDRO MACHIEMMBRADA (1.50X2.30) CON CERRAJERIA | 30d | 2024-10-11 | 2024-11-14 | 338SS | 0d | 3,600 | 03.06.07 |
| 340 | 1.4.6.8 | SUMINISTRO Y COLOCACION DE PUERTAS DE MADERA CEDRO MACHIEMMBRADA (1.50X2.10) BATIENTE | 30d | 2024-10-11 | 2024-11-14 | 339SS | 0d | 2,700 | 03.06.08 |
| 341 | 1.4.6.9 | SUMINISTRO Y COLOCACION DE PUERTAS DE MADERA MACHIEMMBRADA (1.00X2.10) CON FRESQUILLO H=1.10M Y CERRAJERIA | 30d | 2024-10-11 | 2024-11-14 | 340SS | 0d | 21,000 | 03.06.09 |
| 342 | 1.4.6.10 | SUMINISTRO Y COLOCACION DE PUERTAS DE MADERA MACHIEMMBRADA (0.90X2.10) CON FRESQUILLO H=1.10M Y CERRAJERIA | 30d | 2024-10-11 | 2024-11-14 | 341SS | 0d | 5,700 | 03.06.10 |
| 343 | 1.4.6.11 | SUMINISTRO Y COLOCACION DE PUERTAS DE MADERA MACHIEMMBRADA (0.90X2.65) CON FRESQUILLO H=1.10M Y CERRAJERIA | 30d | 2024-10-11 | 2024-11-14 | 342SS | 0d | 1,870 | 03.06.11 |
| 344 | 1.4.6.12 | SUMINISTRO Y COLOCACION DE PUERTAS DE MADERA CONTRAPLACADA (0.70X2.10) CON CERRAJERIA | 30d | 2024-10-11 | 2024-11-14 | 343SS | 0d | 1,400 | 03.06.12 |
| 345 | 1.4.6.13 | SUMINISTRO Y COLOCACION DE REPOSTERO DE MELAMINE TIPO 1 H=0.70M, SEGÚN DISEÑO | 30d | 2024-10-11 | 2024-11-14 | 344SS | 0d | 9,900 | 03.06.13 |
| 346 | 1.4.6.14 | SUMINISTRO Y COLOCACION DE REPOSTERO DE MELAMINE TIPO 2 H=0.70M, SEGÚN DISEÑO | 30d | 2024-10-11 | 2024-11-14 | 345SS | 0d | 11,200 | 03.06.14 |
| 347 | 1.4.6.15 | SUMINISTRO Y COLOCACION DE REPOSTERO DE MELAMINE TIPO 3 H=0.70M, SEGÚN DISEÑO | 30d | 2024-10-11 | 2024-11-14 | 346SS | 0d | 20,400 | 03.06.15 |
| 348 | 1.4.6.16 | SUMINISTRO Y COLOCACION DE REPOSTERO DE MELAMINE TIPO 4 H=0.70M, SEGÚN DISEÑO | 30d | 2024-10-11 | 2024-11-14 | 347SS | 0d | 6,600 | 03.06.16 |
| 349 | 1.4.6.17 | DIVISIONES DE MELAMINE RESISTENTE A LA HUMEDAD TIPO RH SANITARIO CON PUERTA, SEGUN DISEÑO, INCLUYE ACCESORIOS METALICOS | 30d | 2024-10-11 | 2024-11-14 | 348SS | 0d | 52,268.63 | 03.06.17 |
| 350 | 1.4.6.18 | DIVISIONES DE MELAMINE RESISTENTE A LA HUMEDAD TIPO RH SANITARIO EN URINARIO, INCLUYE ACCESORIOS METALICOS | 30d | 2024-10-11 | 2024-11-14 | 349SS | 0d | 3,903.98 | 03.06.18 |
| 351 | 1.4.6.19 | MUROS CON PLANCHAS DE FIBROCEMENTO e=6mm, EN INTERIORES | 30d | 2024-10-11 | 2024-11-14 | 350SS | 0d | 6,058.28 | 03.06.19 |

| ID | WBS | Task | Duration | Start | Finish | Predecessors | Total slack | Cost | Text1 |
| --- | --- | --- | --- | --- | --- | --- | --- | --- | --- |
| 352 | 1.4.7 | **CARPINTERIA METALICA** | 30d | 2024-10-23 | 2024-11-26 |  | 0d | 1,297,211.42 | 03.07 |
| 353 | 1.4.7.1 | SUMINISTRO Y COLOCACION DE PUERTAS METALICAS 1.70X2.60 (TIPO REJA) | 30d | 2024-10-23 | 2024-11-26 | 351SS+10d | 0d | 21,145.28 | 03.07.01 |
| 354 | 1.4.7.2 | SUMINISTRO Y COLOCACION DE PUERTAS METALICAS 1.80X2.60 (TIPO REJA) | 30d | 2024-10-23 | 2024-11-26 | 353SS | 0d | 2,800 | 03.07.02 |
| 355 | 1.4.7.3 | SUMINISTRO Y COLOCACION DE PUERTAS METALICAS 6.0X2.60 (TIPO REJA) | 30d | 2024-10-23 | 2024-11-26 | 354SS | 0d | 9,328.8 | 03.07.03 |
| 356 | 1.4.7.4 | SUMINISTRO Y COLOCACION DE VENTANA ENMARCADA EN ALUMINIO Y VIDRIO DE 6MM CON LAMINA DE SEGURIDAD, INC ACCESORIOS, SEGÚN DISEÑO | 30d | 2024-10-23 | 2024-11-26 | 355SS | 0d | 658,282.95 | 03.07.04 |
| 357 | 1.4.7.5 | SUMINISTRO Y COLOCACION PROTECTOR METALICO PM-1 (3.64X2.45), SEGÚN DISEÑO | 30d | 2024-10-23 | 2024-11-26 | 356SS | 0d | 15,050.82 | 03.07.05 |
| 358 | 1.4.7.6 | SUMINISTRO Y COLOCACION PROTECTOR METALICO PM-2 (3.64X2.17), SEGÚN DISEÑO | 30d | 2024-10-23 | 2024-11-26 | 357SS | 0d | 6,665.31 | 03.07.06 |
| 359 | 1.4.7.7 | SUMINISTRO Y COLOCACION PROTECTOR METALICO PM-3 (3.15X2.20), SEGÚN DISEÑO | 30d | 2024-10-23 | 2024-11-26 | 358SS | 0d | 19,492.7 | 03.07.07 |
| 360 | 1.4.7.8 | SUMINISTRO Y COLOCACION PROTECTOR METALICO PM-4 (3.275X1.10), SEGÚN DISEÑO | 30d | 2024-10-23 | 2024-11-26 | 359SS | 0d | 4,053.24 | 03.07.08 |
| 361 | 1.4.7.9 | SUMINISTRO Y COLOCACION PROTECTOR METALICO PM-5 (1.88X1.10), SEGÚN DISEÑO | 30d | 2024-10-23 | 2024-11-26 | 360SS | 0d | 1,162.56 | 03.07.09 |
| 362 | 1.4.7.10 | SUMINISTRO Y COLOCACION PROTECTOR METALICO PM-6 (1.23X2.20), SEGÚN DISEÑO | 30d | 2024-10-23 | 2024-11-26 | 361SS | 0d | 761.14 | 03.07.10 |
| 363 | 1.4.7.11 | SUMINISTRO Y COLOCACION PROTECTOR METALICO PM-7 (0.85X0.80), SEGÚN DISEÑO | 30d | 2024-10-23 | 2024-11-26 | 362SS | 0d | 3,044.56 | 03.07.11 |
| 364 | 1.4.7.12 | SUMINISTRO Y COLOCACION PROTECTOR METALICO PM-8 (3.15X2.13), SEGÚN DISEÑO | 30d | 2024-10-23 | 2024-11-26 | 363SS | 0d | 7,549 | 03.07.12 |
| 365 | 1.4.7.13 | SUMINISTRO Y COLOCACION PROTECTOR METALICO PM-9 (0.85X0.73), SEGÚN DISEÑO | 30d | 2024-10-23 | 2024-11-26 | 364SS | 0d | 698.12 | 03.07.13 |
| 366 | 1.4.7.14 | SUMINISTRO Y COLOCACION PROTECTOR METALICO PM-10 (1.23X2.13), SEGÚN DISEÑO | 30d | 2024-10-23 | 2024-11-26 | 365SS | 0d | 1,473.86 | 03.07.14 |
| 367 | 1.4.7.15 | SUMINISTRO Y COLOCACION PROTECTOR METALICO PM-11 (3.15X1.03), SEGÚN DISEÑO | 30d | 2024-10-23 | 2024-11-26 | 366SS | 0d | 1,825.22 | 03.07.15 |
| 368 | 1.4.7.16 | SUMINISTRO Y COLOCACION PROTECTOR METALICO PM-12 (3.05X2.20), SEGÚN DISEÑO | 30d | 2024-10-23 | 2024-11-26 | 367SS | 0d | 5,662.17 | 03.07.16 |
| 369 | 1.4.7.17 | SUMINISTRO Y COLOCACION PROTECTOR METALICO PM-13 (1.88X1.03), SEGÚN DISEÑO | 30d | 2024-10-23 | 2024-11-26 | 368SS | 0d | 544.67 | 03.07.17 |
| 370 | 1.4.7.18 | SUMINISTRO Y COLOCACION PASAMANOS METALICA DE ACERO INOXIDABLE Ø 2" SEGÚN DISEÑO | 30d | 2024-10-23 | 2024-11-26 | 369SS | 0d | 31,185.01 | 03.07.18 |
| 371 | 1.4.7.19 | BARANDA METALICA DE ACERO INOXIDABLE Ø 2" TIPO 1 SEGÚN DISEÑO | 30d | 2024-10-23 | 2024-11-26 | 370SS | 0d | 72,667 | 03.07.19 |
| 372 | 1.4.7.20 | BARANDA METALICA DE ACERO INOXIDABLE Ø 2" TIPO 2 SEGÚN DISEÑO H=0.35M | 30d | 2024-10-23 | 2024-11-26 | 371SS | 0d | 110,718.3 | 03.07.20 |
| 373 | 1.4.7.21 | BARANDA METALICA DE ACERO INOXIDABLE Ø 2" TIPO 3 SEGÚN DISEÑO H=0.90M | 30d | 2024-10-23 | 2024-11-26 | 372SS | 0d | 28,660.77 | 03.07.21 |
| 374 | 1.4.7.22 | SUMINISTRO Y COLOCACION DE ESCALERA METALICA TIPO GATO | 30d | 2024-10-23 | 2024-11-26 | 373SS | 0d | 3,135.58 | 03.07.22 |
| 375 | 1.4.7.23 | SUMINISTRO Y COLOCACION DE TAPA JUNTAS DE ALUMINIO DE 6" PARA PISOS | 30d | 2024-10-23 | 2024-11-26 | 374SS | 0d | 4,685.57 | 03.07.23 |
| 376 | 1.4.7.24 | SUMINISTRO Y COLOCACION DE TAPA JUNTAS DE ALUMINIO DE 6" PARA MUROS Y CIELO RASO | 30d | 2024-10-23 | 2024-11-26 | 375SS | 0d | 27,795.43 | 03.07.24 |
| 377 | 1.4.7.25 | SUMINISTRO Y COLOCACION DE TAPA JUNTAS EN SEPARACION DE COBERTURA TIPO U Y TIPO L | 30d | 2024-10-23 | 2024-11-26 | 376SS | 0d | 18,080.68 | 03.07.25 |
| 378 | 1.4.7.26 | SUMINISTRO Y COLOCACION DE ASTA DE BANDERA | 30d | 2024-10-23 | 2024-11-26 | 377SS | 0d | 4,716.68 | 03.07.26 |
| 379 | 1.4.7.27 | CERCO METALICO CON T°F°N° 1"X2" E=2.00MM H=2.60M | 30d | 2024-10-23 | 2024-11-26 | 378SS | 0d | 1,508.73 | 03.07.27 |
| 380 | 1.4.7.28 | SUMINISTRO Y COLOCACION DE PARASOLES METALICOS. SEGÚN DISEÑO INC. ACCESORIOS DE SUJECION Y PINTADO | 30d | 2024-10-23 | 2024-11-26 | 379SS | 0d | 119,597.7 | 03.07.28 |
| 381 | 1.4.7.29 | ESTRUCTURA METALICA PARA SOMBRA EN BANCAS | 30d | 2024-10-23 | 2024-11-26 | 380SS | 0d | 11,880 | 03.07.29 |
| 382 | 1.4.7.30 | BARANDA DE ACERO INOXIDABLE P/SS. HH. DISCAPACITADOS L=1.00M | 30d | 2024-10-23 | 2024-11-26 | 381SS | 0d | 5,319.38 | 03.07.30 |
| 383 | 1.4.7.31 | SUMINISTRO Y COLOCACION DE REJILLA METALICA CON ANGULO DE 1 1/2" x 1 1/2" x 3/16" Y PLATINA 1" x 1" x 1/8" PARA CUNETAS, SEGUN DISEÑO INC. PINTADO | 30d | 2024-10-23 | 2024-11-26 | 382SS | 0d | 95,537.12 | 03.07.31 |
| 384 | 1.4.7.32 | SUM. Y COLOC. DE COLUMNAS DE T°F° N° 4"x4" INC. PINTADO | 30d | 2024-10-23 | 2024-11-26 | 383SS | 0d | 1,648.08 | 03.07.32 |
| 385 | 1.4.7.33 | TAPA METALICA DE PLANCHA ESTRIADA 3/16" LAF (1.10x1.10m), INC. ACCESORIOS DE CERRAJERIA Y PINTADO | 30d | 2024-10-23 | 2024-11-26 | 384SS | 0d | 534.99 | 03.07.33 |

| ID | WBS | Task | Duration | Start | Finish | Predecessors | Total slack | Free slack | Cost | Text1 |
| --- | --- | --- | --- | --- | --- | --- | --- | --- | --- | --- |
| 386 | 1.4.8 | **CERRAJERIA** | 30d | 2024-10-23 | 2024-11-26 |  | 0d |  | 3,241.86 | 03.08 |
| 387 | 1.4.8.1 | SUMINISTRO Y COLOCACION DE BISAGRA ALUMINIZADA DE 4" | 30d | 2024-10-23 | 2024-11-26 | 385SS | 0d |  | 1,676.31 | 03.08.01 |
| 388 | 1.4.8.2 | SUMINISTRO Y COLOCACION DE CERROJO ALUMINIZADO DE 2" INCL. MANIJA | 30d | 2024-10-23 | 2024-11-26 | 387SS | 0d |  | 1,565.55 | 03.08.02 |
| 389 | 1.4.9 | **OTROS** | 122d | 2024-08-20 | 2025-01-08 |  | 19d |  | 1,212,208.28 | 03.09 |
| 390 | 1.4.9.1 | **JUNTAS DE DILATACION** | 25d | 2024-08-26 | 2024-09-23 |  | 111d |  | 269,612.88 | 03.09.01 |
| 391 | 1.4.9.1.1 | JUNTA DE DILATACION e=1" | 25d | 2024-08-26 | 2024-09-23 | 322SS | 111d | 0d | 4,609.45 | 03.09.01.01 |
| 392 | 1.4.9.1.2 | JUNTA DE DILATACION e=3/4" EN LOSAS DEPORTIVA SECUNDARIA Y PATIOS | 25d | 2024-08-26 | 2024-09-23 | 391SS | 111d | 0d | 6,357.09 | 03.09.01.02 |
| 393 | 1.4.9.1.3 | JUNTA VERTICAL CON SELLO ELASTOMERICO e=1" | 25d | 2024-08-26 | 2024-09-23 | 392SS | 111d | 0d | 26,909.36 | 03.09.01.03 |
| 394 | 1.4.9.1.4 | SARDINEL DE VEREDA 0.20x0.40 F'C=175 KG/CM2 | 25d | 2024-08-26 | 2024-09-23 | 393SS | 111d | 0d | 141,263.12 | 03.09.02 |
| 395 | 1.4.9.1.5 | CONCRETO EN GRADERIAS Y RAMPAS PEATONALES F'C=175KG/CM2 E=10CM, ACABADO FROTACHADO FINO Y BRUÑADO INC. SARDINELES | 25d | 2024-08-26 | 2024-09-23 | 394SS | 111d | 0d | 49,963.02 | 03.09.03 |
| 396 | 1.4.9.1.6 | JUNTA DE DILATACION FLEXIBLE e=3/4 CON POLIURETANO EN LOSA DEPORTIVA PRIMARIA | 25d | 2024-08-26 | 2024-09-23 | 395SS | 111d | 0d | 3,874.9 | 03.09.04 |
| 397 | 1.4.9.1.7 | SARDINEL DE (0.20x0.50 ) F'C=175 KG/CM2 EN LOSAS DEPORTIVA | 25d | 2024-08-26 | 2024-09-23 | 396SS | 111d | 0d | 14,269.86 | 03.09.05 |
| 398 | 1.4.9.1.8 | SARDINEL DE (0.20x0.60 ) F'C=175 KG/CM2 | 25d | 2024-08-26 | 2024-09-23 | 397SS | 111d | 0d | 680.46 | 03.09.06 |
| 399 | 1.4.9.1.9 | BRUÑAS e=1cm EN MUROS EXTERIORES E INTERIORES | 25d | 2024-08-26 | 2024-09-23 | 398SS | 111d |  | 21,685.62 | 03.09.07 |
| 400 | 1.4.9.2 | **SEÑALES INFORMATIVAS DE SEGURIDAD** | 20d | 2024-12-17 | 2025-01-08 |  | 19d |  | 581,976.58 | 03.09.08 |
| 401 | 1.4.9.2.1 | SUMINISTRO Y COLOCACION DE SEÑALIZACION ADOSADO A PARED 0.20x0.30m | 8d | 2024-12-17 | 2024-12-25 | 314FS-6d | 19d | 0d | 8,959.16 | 03.09.08.01 |
| 402 | 1.4.9.2.2 | SUMINISTRO Y COLOCACION DE SEÑALIZACION ADOSADO A PARED 0.30x0.40m | 8d | 2024-12-17 | 2024-12-25 | 401SS | 19d | 0d | 700.56 | 03.09.08.02 |
| 403 | 1.4.9.2.3 | SUMINISTRO Y COLOCACION DE EXTINTORES | 20d | 2024-12-17 | 2025-01-08 | 402SS | 19d | 0d | 12,895.36 | 03.09.08.03 |
| 404 | 1.4.9.2.4 | SUMINISTRO Y COLOCACION DE GRASS NATURAL | 20d | 2024-12-17 | 2025-01-08 | 403SS | 19d | 0d | 75,581.99 | 03.09.09 |
| 405 | 1.4.9.2.5 | SUMINISTRO Y COLOCACION DE TIERRA DE CULTIVO h=0.20m | 20d | 2024-12-17 | 2025-01-08 | 404SS | 19d | 0d | 28,519.73 | 03.09.10 |
| 406 | 1.4.9.2.6 | SUMINISTRO Y COLOCACION DE GRASS ARTIFICIAL SINTETICO | 20d | 2024-12-17 | 2025-01-08 | 405SS | 19d | 0d | 447,241.5 | 03.09.11 |
| 407 | 1.4.9.2.7 | SUMINISTRO Y COLOCACION DE GARGOLAS DE C° PREFABRICADA | 20d | 2024-12-17 | 2025-01-08 | 406SS | 19d | 0d | 8,078.28 | 03.09.12 |
| 408 | 1.4.9.3 | **MESAS DE CONCRETO** | 15d | 2024-08-20 | 2024-09-05 |  | 126d |  | 360,618.82 | 03.09.13 |
| 409 | 1.4.9.3.1 | CONCRETO F'C=175 KG/CM2 PARA MESAS | 15d | 2024-08-20 | 2024-09-05 | 316SS | 126d | 0d | 6,709.19 | 03.09.13.01 |
| 410 | 1.4.9.3.2 | ACERO F'Y=4200 KG/CM2 PARA MESAS | 15d | 2024-08-20 | 2024-09-05 | 409SS | 126d | 0d | 5,218.75 | 03.09.13.02 |
| 411 | 1.4.9.3.3 | ENCOFRADO Y DESENCOFRADO DE MESAS DE CONCRETO | 15d | 2024-08-20 | 2024-09-05 | 410SS | 126d | 0d | 8,469.71 | 03.09.13.03 |
| 412 | 1.4.9.3.4 | SUMINISTRO Y COLOCACION DE LETRAS DE ACERO INOXIDABLE SATINADO | 15d | 2024-08-20 | 2024-09-05 | 411SS | 126d | 0d | 3,676.66 | 03.09.14 |
| 413 | 1.4.9.3.5 | SUMINISTRO Y COLOCACION DE INSIGNIA METALICA DE ACERO INOXIDABLE SATINADO | 15d | 2024-08-20 | 2024-09-05 | 412SS | 126d | 0d | 1,225.99 | 03.09.15 |
| 414 | 1.4.9.3.6 | SUMINISTRO Y COLOCACION DE LADRILLO PASTELERO EN COBERTURAS | 15d | 2024-08-20 | 2024-09-05 | 413SS | 126d | 0d | 244,058.85 | 03.09.16 |
| 415 | 1.4.9.3.7 | SUMINISTRO E INSTALACION DE MEMBRANA ASFALTICA EN COBERTURA | 15d | 2024-08-20 | 2024-09-05 | 414SS | 126d | 0d | 4,761.24 | 03.09.17 |
| 416 | 1.4.9.3.8 | CONTRAZOCALO H= 0.10m INC. MEDIA CAÑA PARA EVACUACION PLUVIAL EN CORREDORES Y COBERTURAS | 15d | 2024-08-20 | 2024-09-05 | 415SS | 126d | 0d | 50,403.71 | 03.09.18 |
| 417 | 1.4.9.3.9 | CONCRETO F´C=175KG/CM2 PARA REDIRECCIONAMIENTO DE AGUA PLUVIAL EN CANALETA MEDIA CAÑA | 15d | 2024-08-20 | 2024-09-05 | 416SS | 126d | 0d | 2,994.72 | 03.09.19 |
| 418 | 1.4.9.3.10 | SUMINISTRO Y COLOCACION DE BANCAS DE CONCRETO (1.80x0.45) | 15d | 2024-08-20 | 2024-09-05 | 417SS | 126d | 0d | 24,700 | 03.09.20 |
| 419 | 1.4.9.3.11 | SUMINISTRO Y COLOCACION DE TACHOS PARA BASURA DE 3 DEPOSITOS INC. ACCESORIOS DE ANCLAJE | 15d | 2024-08-20 | 2024-09-05 | 418SS | 126d |  | 8,400 | 03.09.21 |

| ID | WBS | Task | Duration | Start | Finish | Predecessors | Total slack | Free slack | Cost | Text1 |
| --- | --- | --- | --- | --- | --- | --- | --- | --- | --- | --- |
| 420 | 1.4.10 | **TRABAJOS DE REHABILITACION** | 321d | 2023-12-11 | 2024-12-18 |  | 37d |  | 36,905.24 | 03.10 |
| 421 | 1.4.10.1 | REHABILITACION Y COLOCACION DE PUERTAS DE MADERA | 15d | 2023-12-11 | 2023-12-27 | 228SS | 343d | 0d | 1,173.04 | 03.10.01 |
| 422 | 1.4.10.2 | SUMINISTRO Y COLOCACION DE PASAMANO METALICO h=1.00m | 15d | 2023-12-11 | 2023-12-27 | 421SS | 343d | 0d | 1,315.55 | 03.10.02 |
| 423 | 1.4.10.3 | SUMINISTRO Y COLOCACION DE CUMBRERA DE FIBRA VEGETAL | 15d | 2023-12-11 | 2023-12-27 | 422SS | 343d | 0d | 851.88 | 03.10.03 |
| 424 | 1.4.10.4 | SUMINISTRO Y COLOCACION DE COBERTURA LIVIANA DE FIBRA VEGETAL (0.95x2.00m) | 15d | 2023-12-11 | 2023-12-27 | 423SS | 343d | 0d | 12,996.23 | 03.10.04 |
| 425 | 1.4.10.5 | SUMINISTRO Y COLOCACION DE VIGUETAS DE MADERA 2" x 2" | 15d | 2023-12-11 | 2023-12-27 | 424SS | 343d | 0d | 3,023.31 | 03.10.05 |
| 426 | 1.4.10.6 | REHABILITACION DE VENTANA DE MADERA Y VIDRIO | 15d | 2023-12-11 | 2023-12-27 | 425SS | 343d | 0d | 4,993.21 | 03.10.06 |
| 427 | 1.4.10.7 | SUMINISTRO Y COLOCACION DE PUERTA METALICA ENROLLABLE DE 3.94x2.75m | 15d | 2023-12-11 | 2023-12-27 | 426SS | 343d | 0d | 4,000 | 03.10.07 |
| 428 | 1.4.10.8 | SUMINISTRO Y COLOCACION DE PUERTA METALICA ENROLLABLE DE 4.56x2.75m | 15d | 2023-12-11 | 2023-12-27 | 427SS | 343d |  | 4,389 | 03.10.08 |
| 429 | 1.4.10.9 | **DRENAJE PLUVIAL** | 2d | 2024-12-17 | 2024-12-18 |  | 37d |  | 4,163.02 | 03.10.09 |
| 430 | 1.4.10.9.1 | SUMINISTRO E INSTALACION CANALETA DRENAJE PLUVIAL PLANCHA FºGº DE 2mm INC. ACCESORIOS | 2d | 2024-12-17 | 2024-12-18 | 407SS | 37d |  | 4,163.02 | 03.10.09.01 |
| 431 | 1.4.11 | **ACCESORIOS DEPORTIVOS** | 90d | 2024-10-18 | 2025-01-30 |  | 0d |  | 7,627.13 | 03.11 |
| 432 | 1.4.11.1 | ARCOS DE FUTBITO CON TABLERO DE BASQUET (INCLUYE MALLA SEGUN DISEÑO) | 90d | 2024-10-18 | 2025-01-30 | 667SS | 0d |  | 5,084.76 | 03.11.01 |
| 433 | 1.4.11.2 | SUMINISTRO E INSTALACION DE ARCOS C/TUBO 4"X2.5 MM (INCL. MALLA) | 90d | 2024-10-18 | 2025-01-30 | 432SS | 0d |  | 2,542.37 | 03.11.02 |
| 434 | 1.5 | **INSTALACIONES SANITARIAS** | 193d | 2024-05-24 | 2025-01-03 |  | 23d |  | 688,756.77 | 04 |
| 435 | 1.5.1 | **APARATOS SANITARIOS Y ACCESORIOS** | 20d | 2024-12-12 | 2025-01-03 |  | 23d |  | 95,207.86 | 04.01 |
| 436 | 1.5.1.1 | SUMINISTRO DE APARATOS SANITARIO (INODORO) | 20d | 2024-12-12 | 2025-01-03 | 509 | 23d | 0d | 29,783.79 | 04.01.01 |
| 437 | 1.5.1.2 | SUMINISTRO DE APARATOS SANITARIOS (URINARIOS) | 20d | 2024-12-12 | 2025-01-03 | 436SS | 23d | 0d | 4,472.5 | 04.01.02 |
| 438 | 1.5.1.3 | SUMINISTRO DE APARATOS SANITARIOS (LAVAT. MOD. OVALIN) | 20d | 2024-12-12 | 2025-01-03 | 437SS | 23d | 0d | 13,169.3 | 04.01.03 |
| 439 | 1.5.1.4 | SUMINISTRO DE APARATOS SANITARIOS (LAVATORIO C/PEDESTAL) | 20d | 2024-12-12 | 2025-01-03 | 438SS | 23d | 0d | 688.8 | 04.01.04 |
| 440 | 1.5.1.5 | SUMINISTRO DE APARATOS SANITARIOS (LAVADEROS) | 20d | 2024-12-12 | 2025-01-03 | 439SS | 23d | 0d | 9,269 | 04.01.05 |
| 441 | 1.5.1.6 | SUMINISTRO DE APARATOS SANITARIOS (DUCHAS) | 20d | 2024-12-12 | 2025-01-03 | 440SS | 23d | 0d | 1,006.4 | 04.01.06 |
| 442 | 1.5.1.7 | SUMINISTRO DE ACCESORIOS P/INODOROS | 20d | 2024-12-12 | 2025-01-03 | 441SS | 23d | 0d | 2,270.58 | 04.01.07 |
| 443 | 1.5.1.8 | SUMINISTRO DE ACCESORIOS P/URINARIOS | 20d | 2024-12-12 | 2025-01-03 | 442SS | 23d | 0d | 7,153 | 04.01.08 |
| 444 | 1.5.1.9 | SUMINISTRO DE ACCESORIOS P/LAVAT. OVALIN | 20d | 2024-12-12 | 2025-01-03 | 443SS | 23d | 0d | 6,525.4 | 04.01.09 |
| 445 | 1.5.1.10 | SUMINISTRO DE ACCESORIOS P/LAVATORIO C/PEDESTAL | 20d | 2024-12-12 | 2025-01-03 | 444SS | 23d | 0d | 674.7 | 04.01.10 |
| 446 | 1.5.1.11 | SUMINISTRO DE ACCESORIOS P/LAVADEROS | 20d | 2024-12-12 | 2025-01-03 | 445SS | 23d | 0d | 3,485.95 | 04.01.11 |
| 447 | 1.5.1.12 | SUMINISTRO DEACCESORIOS P/DUCHAS | 20d | 2024-12-12 | 2025-01-03 | 446SS | 23d | 0d | 2.88 | 04.01.12 |
| 448 | 1.5.1.13 | INSTALACION DE APARATOS SANITARIOS Y ACCESORIOS | 20d | 2024-12-12 | 2025-01-03 | 447SS | 23d | 0d | 16,705.56 | 04.01.13 |

| ID | WBS | Task | Duration | Start | Finish | Predecessors | Total slack | Free slack | Cost | Text1 |
| --- | --- | --- | --- | --- | --- | --- | --- | --- | --- | --- |
| 449 | 1.5.2 | **SISTEMA DE AGUA FRIA** | 193d | 2024-05-24 | 2025-01-03 |  | 23d |  | 56,152.82 | 04.02 |
| 450 | 1.5.2.1 | **SALIDAS DE AGUA FRIA** | 16d | 2024-05-24 | 2024-06-11 |  | 23d |  | 10,560.96 | 04.02.01 |
| 451 | 1.5.2.1.1 | SALIDA DE AGUA FRIA C-10 Ø 1/2" BRONCE | 16d | 2024-05-24 | 2024-06-11 | 201SS+12d | 23d | 0d | 10,560.96 | 04.02.01.01 |
| 452 | 1.5.2.2 | **REDES DE DISTRIBUCION** | 6d | 2024-06-07 | 2024-06-13 |  | 23d |  | 4,433.5 | 04.02.02 |
| 453 | 1.5.2.2.1 | TUBERIA PVC CLASE 10 SP P/AGUA FRIA D=3/4" | 6d | 2024-06-07 | 2024-06-13 | 451FS-4d | 23d | 0d | 4,433.5 | 04.02.02.01 |
| 454 | 1.5.2.3 | **REDES DE ALIMENTACION** | 20d | 2024-06-12 | 2024-07-04 |  | 23d |  | 9,624.45 | 04.02.03 |
| 455 | 1.5.2.3.1 | TUBERIA PVC ROSCADO C-10 D=2" | 20d | 2024-06-12 | 2024-07-04 | 453FS-2d | 23d | 0d | 3,175.87 | 04.02.03.01 |
| 456 | 1.5.2.3.2 | TUBERIA PVC ROSCADO C-10 D=1 1/2" | 20d | 2024-06-12 | 2024-07-04 | 455SS | 23d | 0d | 3,146.61 | 04.02.03.02 |
| 457 | 1.5.2.3.3 | TUBERIA PVC ROSCADO C-10 D=1" | 20d | 2024-06-12 | 2024-07-04 | 456SS | 23d | 0d | 3,301.97 | 04.02.03.03 |
| 458 | 1.5.2.4 | **ACCESORIOS DE REDES DE AGUA** | 167d | 2024-06-24 | 2025-01-03 |  | 23d |  | 27,493.32 | 04.02.04 |
| 459 | 1.5.2.4.1 | **ACCESORIOS EN REDES DE DISTRIBUCION** | 167d | 2024-06-24 | 2025-01-03 |  | 23d |  | 24,843.83 | 04.02.04.01 |
| 460 | 1.5.2.4.1.1 | SUMINISTRO E INSTALACION DE CODO DE 90° PVC AGUA C-10 3/4" | 16d | 2024-06-24 | 2024-07-11 | 457FS-10d | 23d | 0d | 5,487.3 | 04.02.04.01.01 |
| 461 | 1.5.2.4.1.2 | SUMINISTRO E INSTALACION DE TEE PVC AGUA C-10 3/4" | 16d | 2024-06-24 | 2024-07-11 | 460SS | 23d | 0d | 1,766.56 | 04.02.04.01.02 |
| 462 | 1.5.2.4.1.3 | SUMINISTRO E INSTALACION DE CODO DE BRONCE 1/2" | 16d | 2024-06-24 | 2024-07-11 | 461SS | 23d | 0d | 2,250.96 | 04.02.04.01.03 |
| 463 | 1.5.2.4.1.4 | SUMINISTRO E INSTALACION DE ADAPTADOR PVC AGUA C-10 3/4" | 16d | 2024-06-24 | 2024-07-11 | 462SS | 23d | 0d | 1,945.86 | 04.02.04.01.04 |
| 464 | 1.5.2.4.1.5 | SUMINISTRO E INSTALACION DE NIPLE PVC AGUA C-10 3/4" | 16d | 2024-06-24 | 2024-07-11 | 463SS | 23d | 0d | 1,827.36 | 04.02.04.01.05 |
| 465 | 1.5.2.4.1.6 | SUMINISTRO E INSTALACION DE REDUCCION PVC AGUA C-10 1" A 3/4" | 16d | 2024-06-24 | 2024-07-11 | 464SS | 23d | 0d | 493.5 | 04.02.04.01.06 |
| 466 | 1.5.2.4.1.7 | SUMINISTRO E INSTALACION DE REDUCCION PVC AGUA C-10 3/4 A 1/2" | 16d | 2024-06-24 | 2024-07-11 | 465SS | 174d |  | 2,020.44 | 04.02.04.01.07 |
| 467 | 1.5.2.4.1.8 | SUMINISTRO E INSTALACION DE TUBO DE ABASTO PARA INODORO | 20d | 2024-12-12 | 2025-01-03 | 448SS | 23d | 0d | 2,166.92 | 04.02.04.01.08 |
| 468 | 1.5.2.4.1.9 | SUMINISTRO E INSTALACION DE TUBO DE ABASTO PARA LAVATORIO | 20d | 2024-12-12 | 2025-01-03 | 467SS | 23d |  | 1,864.05 | 04.02.04.01.09 |
| 469 | 1.5.2.4.1.10 | SUMINISTRO E INSTALACION DE TRAMPA PLASTICA C/REGISTRO | 16d | 2024-06-24 | 2024-07-11 | 465SS | 23d | 0d | 3,479.28 | 04.02.04.01.10 |
| 470 | 1.5.2.4.1.11 | SUMINISTRO E INSTALACION DE UNION UNIVERSAL PVC 3/4" | 16d | 2024-06-24 | 2024-07-11 | 469SS | 23d | 0d | 1,541.6 | 04.02.04.01.11 |
| 471 | 1.5.2.4.2 | **ACCESORIOS EN REDES DE ALIMENTACION** | 4d | 2024-07-12 | 2024-07-16 |  | 23d |  | 2,649.49 | 04.02.04.02 |
| 472 | 1.5.2.4.2.1 | SUMINISTRO Y COLOCACION DE CODO 90° PVC SAP Ø 1" | 4d | 2024-07-12 | 2024-07-16 | 470 | 23d | 0d | 628.14 | 04.02.04.02.01 |
| 473 | 1.5.2.4.2.2 | SUMINISTRO Y COLOCACION DE CODO 90° PVC SAP Ø 1 1/2" | 4d | 2024-07-12 | 2024-07-16 | 472SS | 23d | 0d | 257.84 | 04.02.04.02.02 |
| 474 | 1.5.2.4.2.3 | SUMINISTRO Y COLOCACION DE CODO 90° PVC SAP Ø 2" | 4d | 2024-07-12 | 2024-07-16 | 473SS | 23d | 0d | 228.2 | 04.02.04.02.03 |
| 475 | 1.5.2.4.2.4 | SUMINISTRO E INSTALACION DE TEE PVC SAP DE Ø 1" | 4d | 2024-07-12 | 2024-07-16 | 474SS | 23d | 0d | 499.5 | 04.02.04.02.04 |
| 476 | 1.5.2.4.2.5 | SUMINISTRO E INSTALACION DE TEE PVC SAP DE Ø 1 1/2" | 4d | 2024-07-12 | 2024-07-16 | 475SS | 23d | 0d | 183.56 | 04.02.04.02.05 |
| 477 | 1.5.2.4.2.6 | SUMINISTRO E INSTALACION DE TEE PVC SAP DE Ø 2" | 4d | 2024-07-12 | 2024-07-16 | 476SS | 23d | 0d | 334.59 | 04.02.04.02.06 |
| 478 | 1.5.2.4.2.7 | SUMINISTRO E INSTALACION DE REDUCCION PVC AGUA C-10 2" A 1 1/2" | 4d | 2024-07-12 | 2024-07-16 | 477SS | 23d | 0d | 163.8 | 04.02.04.02.07 |
| 479 | 1.5.2.4.2.8 | SUMINISTRO E INSTALACION DE REDUCCION PVC AGUA C-10 2 A 1"" | 4d | 2024-07-12 | 2024-07-16 | 478SS | 23d | 0d | 137.6 | 04.02.04.02.08 |
| 480 | 1.5.2.4.2.9 | SUMINISTRO E INSTALACION DE REDUCCION PVC AGUA C-10 1 1/2" A 1" | 4d | 2024-07-12 | 2024-07-16 | 479SS | 23d | 0d | 216.26 | 04.02.04.02.09 |

| ID | WBS | Task | Duration | Start | Finish | Predecessors | Total slack | Free slack | Cost | Text1 |
| --- | --- | --- | --- | --- | --- | --- | --- | --- | --- | --- |
| 481 | 1.5.2.5 | **VALVULAS** | 6d | 2024-07-17 | 2024-07-23 |  | 23d |  | 4,040.59 | 04.02.05 |
| 482 | 1.5.2.5.1 | VALVULA COMPUERTA PESADA DE BRONCE DE 3/4" | 6d | 2024-07-17 | 2024-07-23 | 480 | 23d | 0d | 4,040.59 | 04.02.05.01 |
| 483 | 1.5.3 | **SISTEMA CONTRA INCENDIO** | 20d | 2024-07-24 | 2024-08-15 |  | 23d |  | 169,013.96 | 04.03 |
| 484 | 1.5.3.1 | TUBERIA DE ACERO AL CARBONO SCH-40 Ø 2 1/2" (ACI) | 20d | 2024-07-24 | 2024-08-15 | 482 | 23d | 0d | 129,912.68 | 04.03.01 |
| 485 | 1.5.3.2 | **ACCESORIOS DE LA RED DE ALIMENTACION** | 20d | 2024-07-24 | 2024-08-15 |  | 23d |  | 1,000.7 | 04.03.02 |
| 486 | 1.5.3.2.1 | SUMINISTRO E INSTALACION DE CODO DE 90º SCH-40 2 1/2" (ACI) | 20d | 2024-07-24 | 2024-08-15 | 484SS | 23d | 0d | 474.46 | 04.03.02.01 |
| 487 | 1.5.3.2.2 | SUMINISTRO E INSTALACION DE TEE SCH-40 2 1/2" (ACI) | 20d | 2024-07-24 | 2024-08-15 | 486SS | 23d | 0d | 526.24 | 04.03.02.02 |
| 488 | 1.5.3.3 | SUMINISTRO E INSTALACION DE GABINETE CONTRA INCENDIO INC. ACCESORIOS | 20d | 2024-07-24 | 2024-08-15 | 487SS | 23d | 0d | 36,175.58 | 04.03.03 |
| 489 | 1.5.3.4 | SUMINISTRO E INSTALACION DE VALVULA SIAMESA Y VALVULA CHECK | 20d | 2024-07-24 | 2024-08-15 | 488SS | 23d | 0d | 1,925 | 04.03.04 |
| 490 | 1.5.4 | **SISTEMA DE DRENAJE PLUVIAL** | 79d | 2024-09-11 | 2024-12-11 |  | 23d |  | 315,223.06 | 04.04 |
| 491 | 1.5.4.1 | **CUNETAS** | 69d | 2024-09-11 | 2024-11-29 |  | 23d |  | 159,708.69 | 04.04.01 |
| 492 | 1.5.4.1.1 | TRAZO, NIVELACION Y REPLANTEO | 2d | 2024-09-11 | 2024-09-12 | 539SS | 23d | 0d | 2,162.86 | 04.04.01.01 |
| 493 | 1.5.4.1.2 | EXCAVACION MANUAL PARA CUNETAS | 20d | 2024-09-13 | 2024-10-05 | 492 | 23d | 0d | 9,627.66 | 04.04.01.02 |
| 494 | 1.5.4.1.3 | MEJORAMIENTO CON MATERIAL DE PRESTAMO (HORMIGON) e=0.15m | 4d | 2024-10-07 | 2024-10-10 | 493 | 23d | 0d | 8,634.01 | 04.04.01.03 |
| 495 | 1.5.4.1.4 | ENCOFRADO Y DESENCOFRADO DE CUENTA | 14d | 2024-10-09 | 2024-10-24 | 494FS-2d | 23d | 0d | 27,256.65 | 04.04.01.04 |
| 496 | 1.5.4.1.5 | CONCRETO F'C= 175 KG/CM2 - PARA CUNETAS | 6d | 2024-10-21 | 2024-10-26 | 495FS-4d | 23d | 0d | 51,930.38 | 04.04.01.05 |
| 497 | 1.5.4.1.6 | CURADO DE ESTRUCTURAS | 12d | 2024-10-21 | 2024-11-02 | 496SS | 23d | 0d | 5,099.81 | 04.04.01.06 |
| 498 | 1.5.4.1.7 | TUBERIA PVC CLASE 10 SP P/AGUA FRIA D=3" | 30d | 2024-10-26 | 2024-11-29 | 497SS+5d | 23d | 0d | 52,423.14 | 04.04.02 |
| 499 | 1.5.4.1.8 | SUMINISTRO E INSTALACION DE CODO DE 90º PVC AGUA C-10 3" | 30d | 2024-10-26 | 2024-11-29 | 498SS | 23d | 0d | 2,574.18 | 04.04.03 |
| 500 | 1.5.4.2 | **DREN PLUVIAL** | 27d | 2024-11-07 | 2024-12-07 |  | 23d |  | 151,418.65 | 04.04.04 |
| 501 | 1.5.4.2.1 | TRAZO, NIVELACION Y REPLANTEO | 2d | 2024-11-07 | 2024-11-08 | 499SS+10d | 23d | 0d | 1,700.64 | 04.04.04.01 |
| 502 | 1.5.4.2.2 | EXCAVACION CON MAQUINARIA PARA DREN PLUVIAL | 4d | 2024-11-09 | 2024-11-13 | 501 | 23d | 0d | 6,732.21 | 04.04.04.02 |
| 503 | 1.5.4.2.3 | ENCOFRADO Y DESENCOFRADO DE CANAL DE DREN PLUVIAL | 8d | 2024-11-12 | 2024-11-20 | 502SS+2d | 23d | 0d | 5,307.21 | 04.04.04.03 |
| 504 | 1.5.4.2.4 | COLOCACION, NIVELACION Y COMPACTACION CON MATERIAL DE PRESTAMO (HORMIGON) e=0.20m | 3d | 2024-11-19 | 2024-11-21 | 503FS-2d | 23d | 0d | 42,461.46 | 04.04.04.04 |
| 505 | 1.5.4.2.5 | COLOCACION, NIVELACION Y COMPACTACION CON MATERIAL DE PRESTAMO (OVER DE 2" A 3") | 5d | 2024-11-21 | 2024-11-26 | 504SS+2d | 23d | 0d | 18,176.49 | 04.04.04.05 |
| 506 | 1.5.4.2.6 | CONCRETO F'C= 175 KG/CM2 - PARA CANAL DE DREN PLUVIAL | 3d | 2024-11-27 | 2024-11-29 | 505 | 23d | 0d | 33,796.04 | 04.04.04.06 |
| 507 | 1.5.4.2.7 | CURADO DE ESTRUCTURAS | 6d | 2024-11-27 | 2024-12-03 | 506SS | 23d | 0d | 1,835.37 | 04.04.04.07 |
| 508 | 1.5.4.2.8 | SUMINISTRO E INSTALACION DE GEOMEMBRANA DE PVC E=0.5 MM | 4d | 2024-12-04 | 2024-12-07 | 507 | 23d | 0d | 41,409.23 | 04.04.04.08 |
| 509 | 1.5.4.3 | TUBERIA PVC P/ALCANTARILLADO D=8" | 3d | 2024-12-09 | 2024-12-11 | 508 | 23d | 0d | 4,095.72 | 04.04.05 |

| ID | WBS | Task | Duration | Start | Finish | Predecessors | Total slack | Free slack | Cost | Text1 |
| --- | --- | --- | --- | --- | --- | --- | --- | --- | --- | --- |
| 510 | 1.5.5 | **DESAGUE Y VENTILACION** | 42d | 2024-07-26 | 2024-09-12 |  | 23d |  | 53,159.07 | 04.05 |
| 511 | 1.5.5.1 | SALIDAS DE DESAGUE DE PVC 4" | 6d | 2024-07-26 | 2024-08-01 | 489SS+2d | 23d | 0d | 3,775.78 | 04.05.01 |
| 512 | 1.5.5.2 | SALIDAS DE DESAGUE DE PVC 2" | 14d | 2024-07-29 | 2024-08-13 | 511SS+2d | 23d | 0d | 6,532.77 | 04.05.02 |
| 513 | 1.5.5.3 | **REDES DE DERIVACION** | 6d | 2024-08-14 | 2024-08-20 |  | 23d |  | 5,853.61 | 04.05.03 |
| 514 | 1.5.5.3.1 | TUBO DE DESAGUE DE PVC Ø 4" | 3d | 2024-08-14 | 2024-08-16 | 512 | 23d | 0d | 3,736.58 | 04.05.03.01 |
| 515 | 1.5.5.3.2 | TUBO DE DESAGUE DE PVC Ø 2" | 3d | 2024-08-17 | 2024-08-20 | 514 | 23d | 0d | 2,117.03 | 04.05.03.02 |
| 516 | 1.5.5.4 | **REDES COLECTORAS** | 20d | 2024-08-15 | 2024-09-06 |  | 28d |  | 13,788.21 | 04.05.04 |
| 517 | 1.5.5.4.1 | TUBO DE DESAGUE DE PVC SAP D=6" | 20d | 2024-08-15 | 2024-09-06 | 515FS-5d | 120d | 0d | 5,774.53 | 04.05.04.01 |
| 518 | 1.5.5.4.2 | TUBO DE DESAGUE DE PVC Ø 4" | 6d | 2024-08-21 | 2024-08-27 | 515 | 23d | 0d | 7,204.83 | 04.05.04.02 |
| 519 | 1.5.5.4.3 | TUBO DE DESAGUE DE PVC Ø 2" | 6d | 2024-08-21 | 2024-08-27 | 518SS | 23d | 0d | 808.85 | 04.05.04.03 |
| 520 | 1.5.5.5 | **ACCESORIOS DE REDES DE DESAGUE** | 10d | 2024-08-26 | 2024-09-05 |  | 23d |  | 10,792.19 | 04.05.05 |
| 521 | 1.5.5.5.1 | SUMINISTRO E INSTALACION DE CODO 90° PVC Ø 4" | 10d | 2024-08-26 | 2024-09-05 | 519FS-2d | 23d | 0d | 1,488.44 | 04.05.05.01 |
| 522 | 1.5.5.5.2 | SUMINISTRO E INSTALACION DE CODO 90° PVC Ø 2" | 10d | 2024-08-26 | 2024-09-05 | 521SS | 23d | 0d | 2,432.7 | 04.05.05.02 |
| 523 | 1.5.5.5.3 | SUMINISTRO E INSTALACION DE TEE PVC 4" | 10d | 2024-08-26 | 2024-09-05 | 522SS | 23d | 0d | 426.92 | 04.05.05.03 |
| 524 | 1.5.5.5.4 | SUMINISTRO E INSTALACION DE TEE PVC 2" | 10d | 2024-08-26 | 2024-09-05 | 523SS | 23d | 0d | 131.1 | 04.05.05.04 |
| 525 | 1.5.5.5.5 | SUMINISTRO E INSTALACION DE REGISTRO ROSCADO DE BRONCE DE Ø 4" | 10d | 2024-08-26 | 2024-09-05 | 524SS | 23d | 0d | 814.9 | 04.05.05.05 |
| 526 | 1.5.5.5.6 | SUMINISTRO E INSTALACION DE REGISTRO ROSCADO DE BRONCE DE Ø 2" | 10d | 2024-08-26 | 2024-09-05 | 525SS | 23d | 0d | 151.65 | 04.05.05.06 |
| 527 | 1.5.5.5.7 | SUMINISTRO Y COLOCACION DE SUMIDERO CON TRAMPA P | 10d | 2024-08-26 | 2024-09-05 | 526SS | 23d | 0d | 624 | 04.05.05.07 |
| 528 | 1.5.5.5.8 | SUMINISTRO E INSTALACIÓN DE YEE SIMPLE 4" | 10d | 2024-08-26 | 2024-09-05 | 527SS | 23d | 0d | 1,893.29 | 04.05.05.08 |
| 529 | 1.5.5.5.9 | SUMINISTRO E INSTALACIÓN DE YEE SIMPLE 2" | 10d | 2024-08-26 | 2024-09-05 | 528SS | 23d | 0d | 529.2 | 04.05.05.09 |
| 530 | 1.5.5.5.10 | SUMINISTRO E INSTALACIÓN DE YEE DOBLE 4" | 10d | 2024-08-26 | 2024-09-05 | 529SS | 23d | 0d | 41.98 | 04.05.05.10 |
| 531 | 1.5.5.5.11 | SUMINISTRO E INSTALACIÓN DE YEE DE 4" A 2" | 10d | 2024-08-26 | 2024-09-05 | 530SS | 23d | 0d | 1,714.65 | 04.05.05.11 |
| 532 | 1.5.5.5.12 | SUMINISTRO E INSTALACIÓN DE SOMBRERO DE VENTILACION 4" | 10d | 2024-08-26 | 2024-09-05 | 531SS | 23d | 0d | 152.94 | 04.05.05.12 |
| 533 | 1.5.5.5.13 | SUMINISTRO E INSTALACIÓN DE SOMBRERO DE VENTILACION 2" | 10d | 2024-08-26 | 2024-09-05 | 532SS | 23d | 0d | 390.42 | 04.05.05.13 |

| ID | WBS | Task | Duration | Start | Finish | Predecessors | Total slack | Free slack | Cost | Text1 |
| --- | --- | --- | --- | --- | --- | --- | --- | --- | --- | --- |
| 534 | 1.5.5.6 | **CAMARAS DE INSPECCION** | 20d | 2024-08-21 | 2024-09-12 |  | 35d |  | 11,882.96 | 04.05.06 |
| 535 | 1.5.5.6.1 | SUMINISTRO E INSTALACION CAJA REGISTRO | 6d | 2024-09-04 | 2024-09-10 | 533FS-2d | 23d | 0d | 4,283.52 | 04.05.06.01 |
| 536 | 1.5.5.6.2 | SUMINISTRO E INSTALACION DE BUZONETA | 20d | 2024-08-21 | 2024-09-12 | 517SS+5d | 120d | 0d | 1,227.5 | 04.05.06.02 |
| 537 | 1.5.5.6.3 | SUMINISTRO E INSTALACION DE BUZON | 20d | 2024-08-21 | 2024-09-12 | 536SS | 120d |  | 6,371.94 | 04.05.06.03 |
| 538 | 1.5.5.7 | **VARIOS** | 2d | 2024-09-11 | 2024-09-12 |  | 23d |  | 533.55 | 04.05.07 |
| 539 | 1.5.5.7.1 | CONEXION DOMICILIARIA DE DESAGUE | 2d | 2024-09-11 | 2024-09-12 | 535 | 23d | 0d | 533.55 | 04.05.07.01 |
| 540 | 1.6 | **INSTALACIONES ELECTRICAS** | 225d | 2023-11-23 | 2024-08-10 |  | 148d |  | 746,282.74 | 05 |
| 541 | 1.6.1 | **TABLEROS ELECTRICOS** | 90d | 2024-03-13 | 2024-06-25 |  | 188d |  | 77,447.57 | 05.01 |
| 542 | 1.6.1.1 | SUMINISTRO Y COLOCACION DE TABLERO GENERAL (TG) | 90d | 2024-03-13 | 2024-06-25 | 624SS+10d | 188d | 0d | 2,606.56 | 05.01.01 |
| 543 | 1.6.1.2 | SUMINISTRO Y COLOCACION DE SUB_TABLERO STG-1A | 90d | 2024-03-13 | 2024-06-25 | 542SS | 188d | 0d | 3,340.06 | 05.01.02 |
| 544 | 1.6.1.3 | SUMINISTRO Y COLOCACION DE SUB_TABLERO STG-1B | 90d | 2024-03-13 | 2024-06-25 | 543SS | 188d | 0d | 2,951.63 | 05.01.03 |
| 545 | 1.6.1.4 | SUMINISTRO Y COLOCACION DE TABLERO DE DISTRIBUCION - TD-01 | 90d | 2024-03-13 | 2024-06-25 | 544SS | 188d | 0d | 920.07 | 05.01.04 |
| 546 | 1.6.1.5 | SUMINISTRO Y COLOCACION DE TABLERO DE DISTRIBUCION - TD-1.01 | 90d | 2024-03-13 | 2024-06-25 | 545SS | 188d | 0d | 1,143.57 | 05.01.05 |
| 547 | 1.6.1.6 | SUMINISTRO Y COLOCACION DE TABLERO DE DISTRIBUCION - TD-1.02 | 90d | 2024-03-13 | 2024-06-25 | 546SS | 188d | 0d | 1,143.57 | 05.01.06 |
| 548 | 1.6.1.7 | SUMINISTRO Y COLOCACION DE TABLERO DE DISTRIBUCION - TD-1.03 | 90d | 2024-03-13 | 2024-06-25 | 547SS | 188d | 0d | 1,027.07 | 05.01.07 |
| 549 | 1.6.1.8 | SUMINISTRO Y COLOCACION DE TABLERO DE DISTRIBUCION - TD-1.03.01 | 90d | 2024-03-13 | 2024-06-25 | 548SS | 188d | 0d | 2,075.07 | 05.01.08 |
| 550 | 1.6.1.9 | SUMINISTRO Y COLOCACION DE TABLERO DE DISTRIBUCION - TD-1.03.02 | 90d | 2024-03-13 | 2024-06-25 | 549SS | 188d | 0d | 869.03 | 05.01.09 |
| 551 | 1.6.1.10 | SUMINISTRO Y COLOCACION DE TABLERO DE DISTRIBUCION - TD-1.03.03 | 90d | 2024-03-13 | 2024-06-25 | 550SS | 188d | 0d | 686.03 | 05.01.10 |
| 552 | 1.6.1.11 | SUMINISTRO Y COLOCACION DE TABLERO DE DISTRIBUCION - TD-1.04 | 90d | 2024-03-13 | 2024-06-25 | 551SS | 188d | 0d | 1,025.57 | 05.01.11 |
| 553 | 1.6.1.12 | SUMINISTRO Y COLOCACION DE TABLERO DE DISTRIBUCION - TD-1.05 | 90d | 2024-03-13 | 2024-06-25 | 552SS | 188d | 0d | 1,340.07 | 05.01.12 |
| 554 | 1.6.1.13 | SUMINISTRO Y COLOCACION DE TABLERO DE DISTRIBUCION - TD-1.06 | 90d | 2024-03-13 | 2024-06-25 | 553SS | 188d | 0d | 1,091.07 | 05.01.13 |
| 555 | 1.6.1.14 | SUMINISTRO Y COLOCACION DE TABLERO DE DISTRIBUCION - TD-1.07 | 90d | 2024-03-13 | 2024-06-25 | 554SS | 188d | 0d | 928.57 | 05.01.14 |
| 556 | 1.6.1.15 | SUMINISTRO Y COLOCACION DE TABLERO DE DISTRIBUCION - TD-1.08 | 90d | 2024-03-13 | 2024-06-25 | 555SS | 188d | 0d | 1,091.07 | 05.01.15 |
| 557 | 1.6.1.16 | SUMINISTRO Y COLOCACION DE TABLERO DE DISTRIBUCION - TD-1.09 | 90d | 2024-03-13 | 2024-06-25 | 556SS | 188d | 0d | 1,028.07 | 05.01.16 |
| 558 | 1.6.1.17 | SUMINISTRO Y COLOCACION DE TABLERO DE DISTRIBUCION - TD-1.10 | 90d | 2024-03-13 | 2024-06-25 | 557SS | 188d | 0d | 1,031.07 | 05.01.17 |
| 559 | 1.6.1.18 | SUMINISTRO Y COLOCACION DE TABLERO DE DISTRIBUCION - TD-1.11 | 90d | 2024-03-13 | 2024-06-25 | 558SS | 188d | 0d | 1,259.53 | 05.01.18 |
| 560 | 1.6.1.19 | SUMINISTRO Y COLOCACION DE TABLERO DE DISTRIBUCION - TD-1.12 | 90d | 2024-03-13 | 2024-06-25 | 559SS | 188d | 0d | 1,031.07 | 05.01.19 |
| 561 | 1.6.1.20 | SUMINISTRO Y COLOCACION DE TABLERO DE DISTRIBUCION - TD-1.13 | 90d | 2024-03-13 | 2024-06-25 | 560SS | 188d | 0d | 842.53 | 05.01.20 |
| 562 | 1.6.1.21 | SUMINISTRO Y COLOCACION DE TABLERO DE DISTRIBUCION - TD-1.14 | 90d | 2024-03-13 | 2024-06-25 | 561SS | 188d | 0d | 990.57 | 05.01.21 |
| 563 | 1.6.1.22 | SUMINISTRO Y COLOCACION DE SUB TABLERO ST-2.1 | 90d | 2024-03-13 | 2024-06-25 | 562SS | 188d | 0d | 1,659.07 | 05.01.22 |
| 564 | 1.6.1.23 | SUMINISTRO Y COLOCACION DE SUB TABLERO ST-2.2 | 90d | 2024-03-13 | 2024-06-25 | 563SS | 188d | 0d | 1,659.07 | 05.01.23 |
| 565 | 1.6.1.24 | SUMINISTRO Y COLOCACION DE TABLERO DE DISTRIBUCION - TD-2.01 | 90d | 2024-03-13 | 2024-06-25 | 564SS | 188d | 0d | 1,057.07 | 05.01.24 |
| 566 | 1.6.1.25 | SUMINISTRO Y COLOCACION DE TABLERO DE DISTRIBUCION - TD-2.02 | 90d | 2024-03-13 | 2024-06-25 | 565SS | 188d | 0d | 1,312.07 | 05.01.25 |
| 567 | 1.6.1.26 | SUMINISTRO Y COLOCACION DE TABLERO DE DISTRIBUCION - TD-2.03 | 90d | 2024-03-13 | 2024-06-25 | 566SS | 188d | 0d | 612.53 | 05.01.26 |
| 568 | 1.6.1.27 | SUMINISTRO Y COLOCACION DE TABLERO DE DISTRIBUCION - TD-2.04 | 90d | 2024-03-13 | 2024-06-25 | 567SS | 188d | 0d | 1,025.57 | 05.01.27 |
| 569 | 1.6.1.28 | SUMINISTRO Y COLOCACION DE TABLERO DE DISTRIBUCION - TD-2.05 | 90d | 2024-03-13 | 2024-06-25 | 568SS | 188d | 0d | 1,025.57 | 05.01.28 |
| 570 | 1.6.1.29 | SUMINISTRO Y COLOCACION DE TABLERO DE DISTRIBUCION - TD-2.06 | 90d | 2024-03-13 | 2024-06-25 | 569SS | 188d | 0d | 1,142.07 | 05.01.29 |
| 571 | 1.6.1.30 | SUMINISTRO Y COLOCACION DE TABLERO DE DISTRIBUCION - TD-2.07 | 90d | 2024-03-13 | 2024-06-25 | 570SS | 188d | 0d | 1,359.03 | 05.01.30 |
| 572 | 1.6.1.31 | SUMINISTRO Y COLOCACION DE TABLERO DE DISTRIBUCION - TD-2.08 | 90d | 2024-03-13 | 2024-06-25 | 571SS | 188d | 0d | 1,186.07 | 05.01.31 |
| 573 | 1.6.1.32 | SUMINISTRO Y COLOCACION DE TABLERO DE DISTRIBUCION - TD-2.09 | 90d | 2024-03-13 | 2024-06-25 | 572SS | 188d | 0d | 1,208.57 | 05.01.32 |
| 574 | 1.6.1.33 | SUMINISTRO Y COLOCACION DE TABLERO DE DISTRIBUCION - TD-2.10 | 90d | 2024-03-13 | 2024-06-25 | 573SS | 188d | 0d | 1,328.57 | 05.01.33 |
| 575 | 1.6.1.34 | SUMINISTRO Y COLOCACION DE TABLERO DE DISTRIBUCION - TD-2.11 | 90d | 2024-03-13 | 2024-06-25 | 574SS | 188d | 0d | 1,328.57 | 05.01.34 |
| 576 | 1.6.1.35 | SUMINISTRO Y COLOCACION DE TABLERO DE DISTRIBUCION - TD-2.12 | 90d | 2024-03-13 | 2024-06-25 | 575SS | 188d | 0d | 959.07 | 05.01.35 |
| 577 | 1.6.1.36 | SUMINISTRO Y COLOCACION DE SUB_TABLERO ST-3.1 | 90d | 2024-03-13 | 2024-06-25 | 576SS | 188d | 0d | 1,385.57 | 05.01.36 |
| 578 | 1.6.1.37 | SUMINISTRO Y COLOCACION DE SUB_TABLERO ST-3.2 | 90d | 2024-03-13 | 2024-06-25 | 577SS | 188d | 0d | 1,647.57 | 05.01.37 |
| 579 | 1.6.1.38 | SUMINISTRO Y COLOCACION DE TABLERO DE DISTRIBUCION - TD-3.01 | 90d | 2024-03-13 | 2024-06-25 | 578SS | 188d | 0d | 1,282.07 | 05.01.38 |
| 580 | 1.6.1.39 | SUMINISTRO Y COLOCACION DE TABLERO DE DISTRIBUCION - TD-3.02 | 90d | 2024-03-13 | 2024-06-25 | 579SS | 188d | 0d | 644.03 | 05.01.39 |
| 581 | 1.6.1.40 | SUMINISTRO Y COLOCACION DE TABLERO DE DISTRIBUCION - TD-3.03 | 90d | 2024-03-13 | 2024-06-25 | 580SS | 188d | 0d | 972.03 | 05.01.40 |
| 582 | 1.6.1.41 | SUMINISTRO Y COLOCACION DE TABLERO DE DISTRIBUCION - TD-3.04 | 90d | 2024-03-13 | 2024-06-25 | 581SS | 188d | 0d | 1,057.07 | 05.01.41 |
| 583 | 1.6.1.42 | SUMINISTRO Y COLOCACION DE TABLERO DE DISTRIBUCION - TD-3.05 | 90d | 2024-03-13 | 2024-06-25 | 582SS | 188d | 0d | 1,022.07 | 05.01.42 |
| 584 | 1.6.1.43 | SUMINISTRO Y COLOCACION DE TABLERO DE DISTRIBUCION - TD-3.06 | 90d | 2024-03-13 | 2024-06-25 | 583SS | 188d | 0d | 1,359.03 | 05.01.43 |
| 585 | 1.6.1.44 | SUMINISTRO Y COLOCACION DE TABLERO DE DISTRIBUCION - TD-3.07 | 90d | 2024-03-13 | 2024-06-25 | 584SS | 188d | 0d | 1,134.03 | 05.01.44 |
| 586 | 1.6.1.45 | SUMINISTRO Y COLOCACION DE TABLERO DE DISTRIBUCION - TD-3.08 | 90d | 2024-03-13 | 2024-06-25 | 585SS | 188d | 0d | 1,208.57 | 05.01.45 |
| 587 | 1.6.1.46 | SUMINISTRO Y COLOCACION DE TABLERO DE DISTRIBUCION - TD-3.09 | 90d | 2024-03-13 | 2024-06-25 | 586SS | 188d | 0d | 1,625.57 | 05.01.46 |
| 588 | 1.6.1.47 | SUMINISTRO Y COLOCACION DE TABLERO DE DISTRIBUCION - TD-3.10 | 90d | 2024-03-13 | 2024-06-25 | 587SS | 188d | 0d | 1,328.57 | 05.01.47 |
| 589 | 1.6.1.48 | SUMINISTRO Y COLOCACION DE TABLERO DE DISTRIBUCION - TD-3.11 | 90d | 2024-03-13 | 2024-06-25 | 588SS | 188d | 0d | 729.07 | 05.01.48 |
| 590 | 1.6.1.49 | SUMINISTRO Y COLOCACION DE SUB_ TABLERO ST-4.2 | 90d | 2024-03-13 | 2024-06-25 | 589SS | 188d | 0d | 990.57 | 05.01.49 |
| 591 | 1.6.1.50 | SUMINISTRO Y COLOCACION DE TABLERO DE DISTRIBUCION - TD-4.01 | 90d | 2024-03-13 | 2024-06-25 | 590SS | 188d | 0d | 1,359.03 | 05.01.50 |
| 592 | 1.6.1.51 | SUMINISTRO Y COLOCACION DE TABLERO DE DISTRIBUCION - TD-4.02 | 90d | 2024-03-13 | 2024-06-25 | 591SS | 188d | 0d | 1,097.57 | 05.01.51 |
| 593 | 1.6.1.52 | SUMINISTRO Y COLOCACION DE TABLERO DE DISTRIBUCION - TD-4.03 | 90d | 2024-03-13 | 2024-06-25 | 592SS | 188d | 0d | 1,097.57 | 05.01.52 |
| 594 | 1.6.1.53 | SUMINISTRO Y COLOCACION DE TABLERO DE DISTRIBUCION - TD-4.04 | 90d | 2024-03-13 | 2024-06-25 | 593SS | 188d | 0d | 697.57 | 05.01.53 |
| 595 | 1.6.1.54 | SUMINISTRO Y COLOCACION DE TABLERO DE CONTROL EQUIPO SOLAR TPS | 90d | 2024-03-13 | 2024-06-25 | 594SS | 188d | 0d | 1,070.57 | 05.01.54 |
| 596 | 1.6.1.55 | SUMINISTRO Y COLOCACION DE TABLERO DE CONTROL ELECTROBOMBA TEB | 90d | 2024-03-13 | 2024-06-25 | 595SS | 188d | 0d | 1,638.43 | 05.01.55 |
| 597 | 1.6.1.56 | SUMINISTRO Y COLOCACION DE BUZON DE CONCRETO | 90d | 2024-03-13 | 2024-06-25 | 596SS | 188d | 0d | 5,665.77 | 05.01.56 |
| 598 | 1.6.1.57 | SUMINISTRO Y COLOCACION DE CAJA BORNERA 03 CIRCUITOS | 90d | 2024-03-13 | 2024-06-25 | 597SS | 188d | 0d | 2,730.42 | 05.01.57 |
| 599 | 1.6.1.58 | SUMINISTRO Y COLOCACION DE CAJA DE PASE 200x200x100 PVC | 90d | 2024-03-13 | 2024-06-25 | 598SS | 188d |  | 420.07 | 05.01.58 |

| ID | WBS | Task | Duration | Start | Finish | Predecessors | Total slack | Free slack | Cost | Text1 |
| --- | --- | --- | --- | --- | --- | --- | --- | --- | --- | --- |
| 600 | 1.6.2 | **CONDUCTORES ALIMENTADORES** | 45d | 2023-11-23 | 2024-01-13 |  | 148d |  | 85,997.66 | 05.02 |
| 601 | 1.6.2.1 | SUMINISTRO E INSTALACION DE CONDUCTOR N2XOH 3-1 x 35 + 25mm2 (MEDIDOR A TG) | 45d | 2023-11-23 | 2024-01-13 | 224SS+60d | 148d | 0d | 1,989.68 | 05.02.01 |
| 602 | 1.6.2.2 | SUMINISTRO E INSTALACION DE CONDUCTOR N2XOH 3-1 x 25 + 25 mm2 (TG - STG) | 45d | 2023-11-23 | 2024-01-13 | 601SS | 148d | 0d | 7,280.88 | 05.02.02 |
| 603 | 1.6.2.3 | SUMINISTRO E INSTALACION DE CONDUCTOR N2XOH 3-1 x 16 +16 mm2 (STG - TD) | 45d | 2023-11-23 | 2024-01-13 | 602SS | 148d | 0d | 12,540.1 | 05.02.03 |
| 604 | 1.6.2.4 | SUMINISTRO E INSTALACION DE CONDUCTOR N2XOH 3-1 x 16 + 1 x 10 (N) | 45d | 2023-11-23 | 2024-01-13 | 603SS | 148d | 0d | 21,615.75 | 05.02.04 |
| 605 | 1.6.2.5 | SUMINISTRO E INSTALACION DE CONDUCTOR N2XOH 3-1 x 10 + 1 x 10 (N) | 45d | 2023-11-23 | 2024-01-13 | 604SS | 148d | 0d | 12,579.65 | 05.02.05 |
| 606 | 1.6.2.6 | SUMINISTRO E INSTALACION DE CONDUCTOR N2XOH 2-1 x 10 mm2 | 45d | 2023-11-23 | 2024-01-13 | 605SS | 148d | 0d | 9,687.6 | 05.02.06 |
| 607 | 1.6.2.7 | SUMINISTRO E INSTALACION DE CONDUCTOR N2XOH (3x6+1x6) mm2 | 45d | 2023-11-23 | 2024-01-13 | 606SS | 148d | 0d | 4,874.48 | 05.02.07 |
| 608 | 1.6.2.8 | SUMINISTRO E INSTALACION DE CONDUCTOR N2XOH 2-1 x 16 mm2 | 45d | 2023-11-23 | 2024-01-13 | 607SS | 148d | 0d | 10,607.1 | 05.02.08 |
| 609 | 1.6.2.9 | SUMINISTRO y TENDIDO CONDUCTOR AUTOPORTANTE CAAI 3-1 x 35 + 1x25mm2 | 45d | 2023-11-23 | 2024-01-13 | 608SS | 148d | 0d | 2,488.84 | 05.02.09 |
| 610 | 1.6.2.10 | SUMINISTRO y TENDIDO CONDUCTOR NLT 2-1 x 06 mm2 | 45d | 2023-11-23 | 2024-01-13 | 609SS | 148d | 0d | 2,333.58 | 05.02.10 |
| 611 | 1.6.3 | **INSTALACION DE INTERIORES** | 180d | 2024-01-15 | 2024-08-10 |  | 148d |  | 296,173 | 05.03 |
| 612 | 1.6.3.1 | SALIDA DE CENTRO DE LUZ PARA UN PUNTO | 70d | 2024-01-15 | 2024-04-04 | 610 | 148d | 0d | 3,094.56 | 05.03.01 |
| 613 | 1.6.3.2 | SALIDA DE CENTRO DE LUZ PARA DOS PUNTOS | 70d | 2024-01-15 | 2024-04-04 | 612SS | 148d | 0d | 9,313.07 | 05.03.02 |
| 614 | 1.6.3.3 | SALIDA DE CENTRO DE LUZ PARA CUATRO PUNTOS | 70d | 2024-01-15 | 2024-04-04 | 613SS | 148d | 0d | 21,259.36 | 05.03.03 |
| 615 | 1.6.3.4 | SALIDA DE CENTRO DE LUZ PARA SEIS PUNTOS | 70d | 2024-01-15 | 2024-04-04 | 614SS | 148d | 0d | 7,810.32 | 05.03.04 |
| 616 | 1.6.3.5 | SUM. E INST. DE EQUIPO LUMINARIA TIPO PANEL LED 48W, ADOSADA AL TECHO | 25d | 2024-07-13 | 2024-08-10 | 653 | 148d | 0d | 135,420 | 05.03.05 |
| 617 | 1.6.3.6 | SUM. E INST. DE EQUIPO LUMINARIA CIRCULAR LED DE 18W | 25d | 2024-07-13 | 2024-08-10 | 616SS | 148d |  | 31,129.15 | 05.03.06 |
| 618 | 1.6.3.7 | SALIDA DE CENTRO DE LUZ CONMUTACION: ESCALERA: ESCALERA Y PASILLOS | 70d | 2024-01-15 | 2024-04-04 | 615SS | 148d | 0d | 1,115.76 | 05.03.07 |
| 619 | 1.6.3.8 | SALIDA PARA PUNTO DE VENTILADORES DE TECHO | 70d | 2024-01-15 | 2024-04-04 | 618SS | 148d | 0d | 12,575.16 | 05.03.08 |
| 620 | 1.6.3.9 | SUMINISTRO E INSTALACION DE VENTILADORES | 70d | 2024-01-15 | 2024-04-04 | 619SS | 148d | 0d | 23,348.52 | 05.03.09 |
| 621 | 1.6.3.10 | SALIDA DE CENTRO DE TOMACORRIENTE h=0.40m | 70d | 2024-01-15 | 2024-04-04 | 620SS | 148d | 0d | 45,937.5 | 05.03.10 |
| 622 | 1.6.3.11 | SALIDA DE CENTRO DE TOMACORRIENTES AREA DE COMPUTADORA | 70d | 2024-01-15 | 2024-04-04 | 621SS | 148d | 0d | 5,169.6 | 05.03.11 |
| 623 | 1.6.4 | **ILUMUNACION PATIO Y EXTERIOR** | 60d | 2024-03-01 | 2024-05-09 |  | 148d |  | 68,219.92 | 05.04 |
| 624 | 1.6.4.1 | SUMINISTRO Y MONTAJE DE POZO A TIERRA, INC. EXCAVACION | 60d | 2024-03-01 | 2024-05-09 | 622FS-30d | 148d | 0d | 15,666.95 | 05.04.01 |
| 625 | 1.6.4.2 | SUMINISTRO Y MONTAJE DE ARTEFACTO BRAQUETE LED (PARTE INTERIOR) | 60d | 2024-03-01 | 2024-05-09 | 624SS | 148d | 0d | 2,956.8 | 05.04.02 |
| 626 | 1.6.4.3 | SUMINISTRO E INSTALACION DE EQUIPO TIPO FAROLA CONICA C/LUMINARIA LED 30W YCONEXIONADO | 60d | 2024-03-01 | 2024-05-09 | 625SS | 148d | 0d | 30,964.68 | 05.04.03 |
| 627 | 1.6.4.4 | POSTE DE CONCRETO ARMADO DE 6m | 60d | 2024-03-01 | 2024-05-09 | 626SS | 148d | 0d | 17,156.88 | 05.04.04 |
| 628 | 1.6.4.5 | SUMINISTRO E INSTALACION DE REFLECTORES LED DE 100 WATTS | 60d | 2024-03-01 | 2024-05-09 | 627SS | 148d | 0d | 1,474.61 | 05.04.05 |

| ID | WBS | Task | Duration | Start | Finish | Predecessors | Total slack | Free slack | Cost | Text1 |
| --- | --- | --- | --- | --- | --- | --- | --- | --- | --- | --- |
| 629 | 1.6.5 | **OTROS** | 20d | 2024-04-23 | 2024-05-15 |  | 148d |  | 23,058.84 | 05.05 |
| 630 | 1.6.5.1 | SUMINISTRO Y MONTAJE DE ELECTROBOMBA Y ACCESORIOS | 20d | 2024-04-23 | 2024-05-15 | 628FS-15d | 148d | 0d | 4,758.46 | 05.05.01 |
| 631 | 1.6.5.2 | SUMINISTRO Y MONTAJE DE ALTAVOZ EXTERIOR PATIO | 20d | 2024-04-23 | 2024-05-15 | 630SS | 148d | 0d | 3,828 | 05.05.02 |
| 632 | 1.6.5.3 | SUMINISTRO Y MONTAJE DE TIMBRE | 20d | 2024-04-23 | 2024-05-15 | 631SS | 148d | 0d | 770.06 | 05.05.03 |
| 633 | 1.6.5.4 | SUMINISTRO Y MONTAJE DE EQUIPO DE LUZ DE EMERGENCIA | 20d | 2024-04-23 | 2024-05-15 | 632SS | 148d | 0d | 12,743.64 | 05.05.04 |
| 634 | 1.6.5.5 | DESMONTAJE DE POSTES | 20d | 2024-04-23 | 2024-05-15 | 633SS | 148d | 0d | 958.68 | 05.05.05 |
| 635 | 1.6.6 | **SISTEMA DE ILUMINACION FOTOVOLTAICO PARA CAMPO DE FULBITO** | 30d | 2024-05-04 | 2024-06-07 |  | 148d |  | 38,354.05 | 05.06 |
| 636 | 1.6.6.1 | SISTEMA DE EQUIPO SOLAR, INCL. PANEL BATERIA, CONTROLADOR, CABLEADO, ACC. | 30d | 2024-05-04 | 2024-06-07 | 634FS-10d | 148d | 0d | 27,958.61 | 05.06.01 |
| 637 | 1.6.6.2 | SUMINISTRO E INSTALACION DE REFLECTOR TIPO LED DE 200W C/EQUIPO INCORPORADO | 30d | 2024-05-04 | 2024-06-07 | 636SS | 148d | 0d | 10,195.44 | 05.06.02 |
| 638 | 1.6.6.3 | SUMINISTRO E NSTALACION DE ACCESRIOS | 30d | 2024-05-04 | 2024-06-07 | 637SS | 148d | 0d | 200 | 05.06.03 |
| 639 | 1.6.7 | **SUMINISTRO DE ILUMINACION PARA CAMPO DE FUTBOL** | 15d | 2024-06-08 | 2024-06-25 |  | 148d |  | 57,222.1 | 05.07 |
| 640 | 1.6.7.1 | SUMINISTRO E INSTALACION DE REFLECTORES LED DE 200 WATTS INCORPORADO | 15d | 2024-06-08 | 2024-06-25 | 638 | 148d | 0d | 44,238.3 | 05.07.01 |
| 641 | 1.6.7.2 | IZAJE Y CIMENTACION DE POSTE DE CONCRETO DE 11m CON PROTECCION CONOCA EN LA BASE | 15d | 2024-06-08 | 2024-06-25 | 640SS | 173d | 0d | 11,575.8 | 05.07.02 |
| 642 | 1.6.7.3 | EXCAVACION DE HOYO PARA POSTES DE CONCRETO DE 11m EN TERRENO NORMAL HOYOS DE 0.6m DE Ø, Y 1.50m DE PROFUNDIDAD | 15d | 2024-06-08 | 2024-06-25 | 641SS | 173d | 0d | 1,048 | 05.07.03 |
| 643 | 1.6.7.4 | EMPALME CONEXIONES ELECTRICAS | 15d | 2024-06-08 | 2024-06-25 | 642SS | 173d | 0d | 360 | 05.07.04 |
| 644 | 1.6.8 | **AIRE ACONDICIONADO** | 15d | 2024-06-26 | 2024-07-12 |  | 173d |  | 36,709.74 | 05.08 |
| 645 | 1.6.8.1 | SUMINISTRO E INSTALACION DE EQUIPO DE AIRE ACONDICIONADO DE 24000 BTU, INC. CONDENSADOR Y ACCESORIOS | 15d | 2024-06-26 | 2024-07-12 | 643 | 173d | 0d | 29,596.22 | 05.08.01 |
| 646 | 1.6.8.2 | SUMINISTRO E INSTALACION DE EQUIPO DE AIRE ACONDICIONADO DE 18000 BTU, INC. CONDENSADOR Y ACCESORIOS | 15d | 2024-06-26 | 2024-07-12 | 645SS | 173d |  | 7,113.52 | 05.08.02 |
| 647 | 1.6.9 | **SUMINISTRO E INSTALACION DE GRUPO GENERADOR** | 65d | 2024-04-23 | 2024-07-06 |  | 175d |  | 38,123.23 | 05.09 |
| 648 | 1.6.9.1 | SUMINISTRO Y MONTAJE DE GRUPO GENERADOR DE 50HP, ENCAPSULADO | 60d | 2024-04-23 | 2024-07-01 | 634SS | 175d | 0d | 27,894.06 | 05.09.01 |
| 649 | 1.6.9.2 | SUMINISTRO E INSTALACION DE TABLERO DE TRANSFERENCIA | 15d | 2024-06-20 | 2024-07-06 | 648FS-10d | 175d | 0d | 10,229.17 | 05.09.02 |
| 650 | 1.6.10 | **SUMINISTRO Y PRUEBAS DE RED ELECTRICA** | 6d | 2024-07-04 | 2024-07-10 |  | 175d |  | 666.14 | 05.10 |
| 651 | 1.6.10.1 | PRUEBAS DE RED ELECTRICAS EN BAJA TENSION | 6d | 2024-07-04 | 2024-07-10 | 649FS-3d | 175d |  | 666.14 | 05.10.01 |
| 652 | 1.6.11 | **SUMINISTRO E INSTALACION DE REDES DATA** | 30d | 2024-06-08 | 2024-07-12 |  | 148d |  | 11,065.58 | 05.11 |
| 653 | 1.6.11.1 | SUMINISTRO Y MONTAJE DE ACCESORIOS PARA SISTEMA DE DATA INTERNET (INCLUYE CONTRATO) | 30d | 2024-06-08 | 2024-07-12 | 640SS | 148d | 0d | 10,702.22 | 05.11.01 |
| 654 | 1.6.11.2 | ESTRUCTURA DE PROYECCION | 30d | 2024-06-08 | 2024-07-12 | 653SS | 158d | 0d | 363.36 | 05.11.02 |

| ID | WBS | Task | Duration | Start | Finish | Predecessors | Total slack | Free slack | Cost | Text1 |
| --- | --- | --- | --- | --- | --- | --- | --- | --- | --- | --- |
| 655 | 1.6.12 | **TRANSPORTE DE MATERIALES** | 10d | 2023-11-23 | 2023-12-04 |  | 363d |  | 3,500 | 05.12 |
| 656 | 1.6.12.1 | TRANSPORTE DE MATERIALES, EXPED. REPLANTEO | 10d | 2023-11-23 | 2023-12-04 | 601SS | 363d |  | 3,500 | 05.12.01 |
| 657 | 1.6.13 | **SEGURIDAD DE OBRA** | 200d | 2023-11-23 | 2024-07-12 |  | 173d |  | 800 | 05.13 |
| 658 | 1.6.13.1 | SEÑALIZACION DE RIESGO ELECTRICO | 200d | 2023-11-23 | 2024-07-12 | 601SS | 173d |  | 800 | 05.13.01 |
| 659 | 1.6.14 | **DERECHO DE CONEXION - ENOSA** | 45d | 2024-06-08 | 2024-07-30 |  | 158d |  | 2,771.11 | 05.14 |
| 660 | 1.6.14.1 | DERECHO DE RECONEXION - ENOSA | 45d | 2024-06-08 | 2024-07-30 | 654SS | 158d | 0d | 660 | 05.14.01 |
| 661 | 1.6.14.2 | REUBICACION DE ACOMETIDA TRIFASICA (ESP. TECNICAS) | 45d | 2024-06-08 | 2024-07-30 | 660SS | 158d | 0d | 2,111.11 | 05.14.02 |
| 662 | 1.6.15 | **PARARRAYOS** | 45d | 2024-06-08 | 2024-07-30 |  | 158d |  | 6,173.8 | 05.15 |
| 663 | 1.6.15.1 | SUMINISTRO Y MONTAJE DE PARARRAYOS | 45d | 2024-06-08 | 2024-07-30 | 661SS | 158d |  | 6,173.8 | 05.15.01 |
| 664 | 1.7 | **MOBILIARIO Y EQUIPAMIENTO** | 90d | 2024-10-18 | 2025-01-30 |  | 0d |  | 3,115,166.73 | 06 |
| 665 | 1.7.1 | **MOBILIARIO** | 90d | 2024-10-18 | 2025-01-30 |  | 0d |  | 1,857,514.92 | 06.01 |
| 666 | 1.7.1.1 | **MESAS** | 90d | 2024-10-18 | 2025-01-30 |  | 0d |  | 611,125.9 | 06.01.01 |
| 667 | 1.7.1.1.1 | MESA RECTANGULAR PARA ESTUDIANTE (0.60 M X 0.50 M X 0.56 M) | 90d | 2024-10-18 | 2025-01-30 | 305SS-12d | 0d |  | 74,025 | 06.01.01.01 |
| 668 | 1.7.1.1.2 | MESA RECTANGULAR PARA ESTUDIANTE (0.60 M X 0.50 M X 0.61 M) | 90d | 2024-10-18 | 2025-01-30 | 667SS | 0d |  | 84,600 | 06.01.01.02 |
| 669 | 1.7.1.1.3 | MESA RECTANGULAR PARA ESTUDIANTE (0.60 M X 0.50 M X 0.66 M) | 90d | 2024-10-18 | 2025-01-30 | 668SS | 0d |  | 87,420 | 06.01.01.03 |
| 670 | 1.7.1.1.4 | MESA RECTANGULAR PARA ESTUDIANTE (0.60 M X 0.50 M X 0.69 M) | 90d | 2024-10-18 | 2025-01-30 | 669SS | 0d |  | 95,175 | 06.01.01.04 |
| 671 | 1.7.1.1.5 | MESA RECTANGULAR PARA ESTUDIANTE (0.60 M X 0.50 M X 0.72 M) | 90d | 2024-10-18 | 2025-01-30 | 670SS | 0d |  | 90,240 | 06.01.01.05 |
| 672 | 1.7.1.1.6 | MESA RECTANGULAR PARA ESTUDIANTE (0.60 M X 0.50 M X 0.75 M) | 90d | 2024-10-18 | 2025-01-30 | 671SS | 0d |  | 42,300 | 06.01.01.06 |
| 673 | 1.7.1.1.7 | MESA RECTANGULAR PARA DOCENTE (1.00 M X 0.50 M X 0.75 M) | 90d | 2024-10-18 | 2025-01-30 | 672SS | 0d |  | 38,981.8 | 06.01.01.07 |
| 674 | 1.7.1.1.8 | MESA RECTANGULAR PARA ESTUDIANTE (0.90 M X 0.45 M X 0.75 M) | 90d | 2024-10-18 | 2025-01-30 | 673SS | 0d |  | 1,762.5 | 06.01.01.08 |
| 675 | 1.7.1.1.9 | MESA RECTANGULAR DE (1.20 M X 0.80 M X 0.75 M) | 90d | 2024-10-18 | 2025-01-30 | 674SS | 0d |  | 9,047.5 | 06.01.01.09 |
| 676 | 1.7.1.1.10 | MESA RECTANGULAR REGULABLE PARA ESTUDIANTE (1.50 M X 0.90 M X 0.69 M A 0.75 M) | 90d | 2024-10-18 | 2025-01-30 | 675SS | 0d |  | 1,762.5 | 06.01.01.10 |
| 677 | 1.7.1.1.11 | MESA RECTANGULAR REGULABLE PARA 6 ESTUDIANTES (2.00 M X 1.00 M X 0.56 M A 0.66 M) | 90d | 2024-10-18 | 2025-01-30 | 676SS | 0d |  | 23,500 | 06.01.01.11 |
| 678 | 1.7.1.1.12 | MESA RECTANGULAR REGULABLE PARA 6 ESTUDIANTES (2.00 M X 1.00 M X 0.69 M A 0.75 M) | 90d | 2024-10-18 | 2025-01-30 | 677SS | 0d |  | 58,750 | 06.01.01.12 |
| 679 | 1.7.1.1.13 | MESA DE CENTRO O DE REVISTAS | 90d | 2024-10-18 | 2025-01-30 | 678SS | 0d |  | 1,120 | 06.01.01.13 |
| 680 | 1.7.1.1.14 | MESA DE TRABAJO (2.40 M X 0.60 M) | 90d | 2024-10-18 | 2025-01-30 | 679SS | 0d |  | 470.4 | 06.01.01.14 |
| 681 | 1.7.1.1.15 | MESAS MODULARES (1.00 M X 1.00 M) | 90d | 2024-10-18 | 2025-01-30 | 680SS | 0d |  | 1,971.2 | 06.01.01.15 |

| ID | WBS | Task | Duration | Start | Finish | Predecessors | Total slack | Cost | Text1 |
| --- | --- | --- | --- | --- | --- | --- | --- | --- | --- |
| 682 | 1.7.1.2 | **ESCRITORIOS** | 90d | 2024-10-18 | 2025-01-30 |  | 0d | 38,900 | 06.01.02 |
| 683 | 1.7.1.2.1 | ESCRITORIO CON CAJONERA PARA DOCENTE (1.00 M X 0.50 M X 0.75 M) | 90d | 2024-10-18 | 2025-01-30 | 681SS | 0d | 19,500 | 06.01.02.01 |
| 684 | 1.7.1.2.2 | ESCRITORIO PARA COMPUTADORA (1.00 M X 0.60 M X 0.75 M) | 90d | 2024-10-18 | 2025-01-30 | 683SS | 0d | 18,200 | 06.01.02.02 |
| 685 | 1.7.1.2.3 | ESCRITORIO PARA COMPUTADORA (0.80 M X 0.60 M X 0.75 M) | 90d | 2024-10-18 | 2025-01-30 | 684SS | 0d | 1,200 | 06.01.02.03 |
| 686 | 1.7.1.3 | **SILLAS** | 90d | 2024-10-18 | 2025-01-30 |  | 0d | 581,904.7 | 06.01.03 |
| 687 | 1.7.1.3.1 | SILLA PARA ESTUDIANTE (0.27 M X 0.32 M X 0.30 M) | 90d | 2024-10-18 | 2025-01-30 | 685SS | 0d | 51,817.5 | 06.01.03.01 |
| 688 | 1.7.1.3.2 | SILLA PARA ESTUDIANTE (0.30 M X 0.34 M X 0.34 M) | 90d | 2024-10-18 | 2025-01-30 | 687SS | 0d | 59,220 | 06.01.03.02 |
| 689 | 1.7.1.3.3 | SILLA PARA ESTUDIANTE (0.33 M X 0.36 M X 0.36 M) | 90d | 2024-10-18 | 2025-01-30 | 688SS | 0d | 62,040 | 06.01.03.03 |
| 690 | 1.7.1.3.4 | SILLA PARA ESTUDIANTE (0.36 M X 0.38 M X 0.39 M) | 90d | 2024-10-18 | 2025-01-30 | 689SS | 0d | 79,312.5 | 06.01.03.04 |
| 691 | 1.7.1.3.5 | SILLA PARA ESTUDIANTE (0.38 M X 0.40 M X 0.42 M) | 90d | 2024-10-18 | 2025-01-30 | 690SS | 0d | 70,500 | 06.01.03.05 |
| 692 | 1.7.1.3.6 | SILLA PARA ESTUDIANTE (0.38 M X 0.41 M X 0.45 M) | 90d | 2024-10-18 | 2025-01-30 | 691SS | 0d | 36,660 | 06.01.03.06 |
| 693 | 1.7.1.3.7 | SILLA REGULABLE 3 NIVELES PARA ESTUDIANTE (0.33 M X 0.36 M X 0.30 M A 0.36 M) | 90d | 2024-10-18 | 2025-01-30 | 692SS | 0d | 42,300 | 06.01.03.07 |
| 694 | 1.7.1.3.8 | SILLA REGULABLE 3 NIVELES PARA ESTUDIANTE (0.38 M X 0.41 M X 0.39M A 0.45 M) | 90d | 2024-10-18 | 2025-01-30 | 693SS | 0d | 101,520 | 06.01.03.08 |
| 695 | 1.7.1.3.9 | SILLA PARA DOCENTE (0.40 M X 0.36 M X 0.45 M) | 90d | 2024-10-18 | 2025-01-30 | 694SS | 0d | 30,855.5 | 06.01.03.09 |
| 696 | 1.7.1.3.10 | BANCOS DE MADERA | 90d | 2024-10-18 | 2025-01-30 | 695SS | 0d | 7,392 | 06.01.03.10 |
| 697 | 1.7.1.3.11 | SILLAS APILABLES | 90d | 2024-10-18 | 2025-01-30 | 696SS | 0d | 28,828.8 | 06.01.03.11 |
| 698 | 1.7.1.3.12 | SILLÓN (0.60 M X 0.55 M X 0.44 M) | 90d | 2024-10-18 | 2025-01-30 | 697SS | 0d | 5,220 | 06.01.03.12 |
| 699 | 1.7.1.3.13 | SILLA GIRATORIA | 90d | 2024-10-18 | 2025-01-30 | 698SS | 0d | 3,024 | 06.01.03.13 |
| 700 | 1.7.1.3.14 | SILLA GERENCIAL GIRATORIA | 90d | 2024-10-18 | 2025-01-30 | 699SS | 0d | 459.2 | 06.01.03.14 |
| 701 | 1.7.1.3.15 | SOFA DOBLE | 90d | 2024-10-18 | 2025-01-30 | 700SS | 0d | 2,755.2 | 06.01.03.15 |
| 702 | 1.7.1.4 | **MUEBLES PARA GUARDADO** | 90d | 2024-10-18 | 2025-01-30 |  | 0d | 351,759.2 | 06.01.04 |
| 703 | 1.7.1.4.1 | ARMARIO 4 DIVISIONES PARA DOCENTE (0.90 M X 0.45 M X 1.80 M) | 90d | 2024-10-18 | 2025-01-30 | 701SS | 0d | 105,300 | 06.01.04.01 |
| 704 | 1.7.1.4.2 | ARMARIO 5 DIVISIONES PARA DOCENTE (0.90 M X 0.45 M X 1.80 M) | 90d | 2024-10-18 | 2025-01-30 | 703SS | 0d | 1,400 | 06.01.04.02 |
| 705 | 1.7.1.4.3 | ESTANTE 4 DIVISIONES PARA ESTUDIANTE (0.80 M X 0.30 M X 1.50 M) | 90d | 2024-10-18 | 2025-01-30 | 704SS | 0d | 58,800 | 06.01.04.03 |
| 706 | 1.7.1.4.4 | ESTANTE 5 DIVISIONES (0.80 M X 0.30 M X 1.50 M) | 90d | 2024-10-18 | 2025-01-30 | 705SS | 0d | 1,300 | 06.01.04.04 |
| 707 | 1.7.1.4.5 | CASILLEROS PARA ESTUDIANTE (1.20 M X 0.40 M X 1.20 M) | 90d | 2024-10-18 | 2025-01-30 | 706SS | 0d | 23,312.8 | 06.01.04.05 |
| 708 | 1.7.1.4.6 | CASILLEROS PARA ESTUDIANTE (1.20 M X 0.40 M X 1.80 M) | 90d | 2024-10-18 | 2025-01-30 | 707SS | 0d | 29,400 | 06.01.04.06 |
| 709 | 1.7.1.4.7 | EXHIBIDOR DE LIBROS 2 DIVISIONES (0.90 M X 0.40 M X 0.90 M) | 90d | 2024-10-18 | 2025-01-30 | 708SS | 0d | 46,816 | 06.01.04.07 |
| 710 | 1.7.1.4.8 | EXHIBIDOR DE LIBROS (1.20 M X 0.40 M X 0.85 M) | 90d | 2024-10-18 | 2025-01-30 | 709SS | 0d | 11,424 | 06.01.04.08 |
| 711 | 1.7.1.4.9 | MUEBLE ALTO 2 DIVISIONES (0.90 M X 0.40 M X 0.50 M) | 90d | 2024-10-18 | 2025-01-30 | 710SS | 0d | 41,888 | 06.01.04.09 |
| 712 | 1.7.1.4.10 | MUEBLE BAJO 2 DIVISIONES (0.80 M X 0.40 M X 1.00 M) | 90d | 2024-10-18 | 2025-01-30 | 711SS | 0d | 1,948.8 | 06.01.04.10 |
| 713 | 1.7.1.4.11 | MUEBLE BAJO 2 DIVISIONES (0.90 M X 0.40 M X 1.00 M) | 90d | 2024-10-18 | 2025-01-30 | 712SS | 0d | 29,881.6 | 06.01.04.11 |
| 714 | 1.7.1.4.12 | ESTANTES MOBILES (0.80x3.00 m) | 90d | 2024-10-18 | 2025-01-30 | 713SS | 0d | 288 | 06.01.04.12 |

| ID | WBS | Task | Duration | Start | Finish | Predecessors | Total slack | Cost | Text1 |
| --- | --- | --- | --- | --- | --- | --- | --- | --- | --- |
| 715 | 1.7.1.5 | **PIZARRA ACRILICA** | 90d | 2024-10-18 | 2025-01-30 |  | 0d | 137,003.52 | 06.01.05 |
| 716 | 1.7.1.5.1 | PIZARRA ACRÍLICA DE (3.20 M X 1.20 M) | 90d | 2024-10-18 | 2025-01-30 | 714SS | 0d | 133,046.4 | 06.01.05.01 |
| 717 | 1.7.1.5.2 | PIZARRA ACRÍLICA DE (1.80 M X 1.20 M) | 90d | 2024-10-18 | 2025-01-30 | 716SS | 0d | 3,957.12 | 06.01.05.02 |
| 718 | 1.7.1.6 | **PANTALLA ECRAN** | 90d | 2024-10-18 | 2025-01-30 |  | 0d | 86,240 | 06.01.06 |
| 719 | 1.7.1.6.1 | PANTALLA ECRAN RETRACTIL DE 72" | 90d | 2024-10-18 | 2025-01-30 | 717SS | 0d | 86,240 | 06.01.06.01 |
| 720 | 1.7.1.7 | **RACK** | 90d | 2024-10-18 | 2025-01-30 |  | 0d | 8,620 | 06.01.07 |
| 721 | 1.7.1.7.1 | RACK PARA PROYECTOR MULTIMEDIA | 90d | 2024-10-18 | 2025-01-30 | 719SS | 0d | 6,160 | 06.01.07.01 |
| 722 | 1.7.1.7.2 | RACK PARA TV Y REPRODUCTOR BLU - RAY | 90d | 2024-10-18 | 2025-01-30 | 721SS | 0d | 1,508 | 06.01.07.02 |
| 723 | 1.7.1.7.3 | RACK PARA LAPTOPS (0.60 M X 0.45 M) DE CAPACIDAD 16 LAPTOPS | 90d | 2024-10-18 | 2025-01-30 | 722SS | 0d | 952 | 06.01.07.03 |
| 724 | 1.7.1.8 | **GABINETE** | 90d | 2024-10-18 | 2025-01-30 |  | 0d | 3,248 | 06.01.08 |
| 725 | 1.7.1.8.1 | GABINETE 9RU PARA EMPOTRAR INC. RACK | 90d | 2024-10-18 | 2025-01-30 | 723SS | 0d | 3,248 | 06.01.08.01 |
| 726 | 1.7.1.9 | **MOBILIARIO COMPLEMENTARIO** | 90d | 2024-10-18 | 2025-01-30 |  | 0d | 38,713.6 | 06.01.09 |
| 727 | 1.7.1.9.1 | BOTIQUIN | 90d | 2024-10-18 | 2025-01-30 | 725SS | 0d | 224 | 06.01.09.01 |
| 728 | 1.7.1.9.2 | COCHE DE MÚLTIPLES USOS | 90d | 2024-10-18 | 2025-01-30 | 727SS | 0d | 470.4 | 06.01.09.02 |
| 729 | 1.7.1.9.3 | CAMILLA RODANTE (0.70 M X 1.80 M) | 90d | 2024-10-18 | 2025-01-30 | 728SS | 0d | 672 | 06.01.09.03 |
| 730 | 1.7.1.9.4 | ANAQUELES METÁLICOS (0.95 M X 0.45 M) | 90d | 2024-10-18 | 2025-01-30 | 729SS | 0d | 9,363.2 | 06.01.09.04 |
| 731 | 1.7.1.9.5 | UTENSILIOS DE COCINA | 90d | 2024-10-18 | 2025-01-30 | 730SS | 0d | 1,120 | 06.01.09.05 |
| 732 | 1.7.1.9.6 | JUEGO DE OLLAS INDUSTRIALES | 90d | 2024-10-18 | 2025-01-30 | 731SS | 0d | 9,000 | 06.01.09.06 |
| 733 | 1.7.1.9.7 | JUEGO DE CUBIERTOS (CUCHARA, CUCHARITA, TENEDOR Y CUCHILLO) | 90d | 2024-10-18 | 2025-01-30 | 732SS | 0d | 4,390.4 | 06.01.09.07 |
| 734 | 1.7.1.9.8 | VAJILLA ( PLATO TENDIDO, PLATO HONDO, VASO Y TASA) | 90d | 2024-10-18 | 2025-01-30 | 733SS | 0d | 6,585.6 | 06.01.09.08 |
| 735 | 1.7.1.9.9 | LOCKERS (0.40 M X 0.45 M) | 90d | 2024-10-18 | 2025-01-30 | 734SS | 0d | 5,376 | 06.01.09.09 |
| 736 | 1.7.1.9.10 | ARCHIVADORES 0.45 M X 0.70 M | 90d | 2024-10-18 | 2025-01-30 | 735SS | 0d | 1,512 | 06.01.09.10 |
| 737 | 1.7.2 | **EQUIPAMIENTO** | 90d | 2024-10-18 | 2025-01-30 |  | 0d | 1,212,851.81 | 06.02 |
| 738 | 1.7.2.1 | **EQUIPOS MULTIMEDIA** | 90d | 2024-10-18 | 2025-01-30 |  | 0d | 106,556 | 06.02.01 |
| 739 | 1.7.2.1.1 | PROYECTOR MULTIMEDIA | 90d | 2024-10-18 | 2025-01-30 | 736SS | 0d | 94,556 | 06.02.01.01 |
| 740 | 1.7.2.1.2 | IMPRESORA MULTIFUNCIONAL | 90d | 2024-10-18 | 2025-01-30 | 739SS | 0d | 12,000 | 06.02.01.02 |

| ID | WBS | Task | Duration | Start | Finish | Predecessors | Total slack | Cost | Text1 |
| --- | --- | --- | --- | --- | --- | --- | --- | --- | --- |
| 741 | 1.7.2.2 | **PC Y/O LAPTOP** | 90d | 2024-10-18 | 2025-01-30 |  | 0d | 671,558 | 06.02.02 |
| 742 | 1.7.2.2.1 | SWITCH 48 PUERTOS 10/100/1000 Mbps | 90d | 2024-10-18 | 2025-01-30 | 740SS | 0d | 3,808 | 06.02.02.01 |
| 743 | 1.7.2.2.2 | PC- CORE I7 3.4 GHZ, MONITOR 24" FHD, RAM 16GB, DISCO ITB + TECLADO Y MOUSE | 90d | 2024-10-18 | 2025-01-30 | 742SS | 0d | 51,750 | 06.02.02.02 |
| 744 | 1.7.2.2.3 | LAPTOP CORE I5 -10 GENERACION, RAM 8GB, 512 GB, PANTALLA 15.6" + MOUSE | 90d | 2024-10-18 | 2025-01-30 | 743SS | 0d | 616,000 | 06.02.02.03 |
| 745 | 1.7.2.3 | **TV Y EQUIPOS ELECTRICOS** | 90d | 2024-10-18 | 2025-01-30 |  | 0d | 76,770 | 06.02.03 |
| 746 | 1.7.2.3.1 | TELEVISOR DE 55" HD SMART TV | 90d | 2024-10-18 | 2025-01-30 | 744SS | 0d | 18,250 | 06.02.03.01 |
| 747 | 1.7.2.3.2 | REPRODUCTOR BLU - RAY | 90d | 2024-10-18 | 2025-01-30 | 746SS | 0d | 2,128 | 06.02.03.02 |
| 748 | 1.7.2.3.3 | CÁMARA FOTOGRÁFICA | 90d | 2024-10-18 | 2025-01-30 | 747SS | 0d | 10,640 | 06.02.03.03 |
| 749 | 1.7.2.3.4 | PIZARRA INTERACTIVA | 90d | 2024-10-18 | 2025-01-30 | 748SS | 0d | 31,000 | 06.02.03.04 |
| 750 | 1.7.2.3.5 | ESTABILIZADOR | 90d | 2024-10-18 | 2025-01-30 | 749SS | 0d | 2,040 | 06.02.03.05 |
| 751 | 1.7.2.3.6 | POWER RACK | 90d | 2024-10-18 | 2025-01-30 | 750SS | 0d | 672 | 06.02.03.06 |
| 752 | 1.7.2.3.7 | UPS 1000VA, 600W | 90d | 2024-10-18 | 2025-01-30 | 751SS | 0d | 2,800 | 06.02.03.07 |
| 753 | 1.7.2.3.8 | UNIDAD DE DISTRIBUCIÓN ENERGÉTICA PDU ACCESS POINT DE ROUTER AC1200/2.4 Y 5GHZ | 90d | 2024-10-18 | 2025-01-30 | 752SS | 0d | 9,240 | 06.02.03.08 |
| 754 | 1.7.2.4 | **EQUIPO LABORATORIO** | 90d | 2024-10-18 | 2025-01-30 |  | 0d | 73,734.6 | 06.02.04 |
| 755 | 1.7.2.4.1 | BALANZA DE PRECISIÓN | 90d | 2024-10-18 | 2025-01-30 | 753SS | 0d | 6,993 | 06.02.04.01 |
| 756 | 1.7.2.4.2 | ESTERILIZADOR | 90d | 2024-10-18 | 2025-01-30 | 755SS | 0d | 4,032 | 06.02.04.02 |
| 757 | 1.7.2.4.3 | CENTRIFUGA | 90d | 2024-10-18 | 2025-01-30 | 756SS | 0d | 5,264 | 06.02.04.03 |
| 758 | 1.7.2.4.4 | DESTILADORA DE AGUA | 90d | 2024-10-18 | 2025-01-30 | 757SS | 0d | 4,368 | 06.02.04.04 |
| 759 | 1.7.2.4.5 | MEDIDOR PORTÁTIL DE PH | 90d | 2024-10-18 | 2025-01-30 | 758SS | 0d | 8,711 | 06.02.04.05 |
| 760 | 1.7.2.4.6 | EQUIPO BAÑO MARÍA | 90d | 2024-10-18 | 2025-01-30 | 759SS | 0d | 3,920 | 06.02.04.06 |
| 761 | 1.7.2.4.7 | MICROSCOPIO DIGITAL | 90d | 2024-10-18 | 2025-01-30 | 760SS | 0d | 8,929.1 | 06.02.04.07 |
| 762 | 1.7.2.4.8 | MICROSCOPIO BINOCULARES | 90d | 2024-10-18 | 2025-01-30 | 761SS | 0d | 3,785.6 | 06.02.04.08 |
| 763 | 1.7.2.4.9 | TERMÓMETRO TIPO LAPICERO | 90d | 2024-10-18 | 2025-01-30 | 762SS | 0d | 1,770.3 | 06.02.04.09 |
| 764 | 1.7.2.4.10 | ESQUELETO HUMANO INTERACTIVO | 90d | 2024-10-18 | 2025-01-30 | 763SS | 0d | 5,488 | 06.02.04.10 |
| 765 | 1.7.2.4.11 | MAQUETAS CIRCUITOS ELÉCTRICOS Y ELECTRÓNICOS | 90d | 2024-10-18 | 2025-01-30 | 764SS | 0d | 13,686.4 | 06.02.04.11 |
| 766 | 1.7.2.4.12 | KIT PARA ESTUDIO DE CÓDIGO GENÉTICO | 90d | 2024-10-18 | 2025-01-30 | 765SS | 0d | 6,787.2 | 06.02.04.12 |

| ID | WBS | Task | Duration | Start | Finish | Predecessors | Total slack | Cost | Text1 |
| --- | --- | --- | --- | --- | --- | --- | --- | --- | --- |
| 767 | 1.7.2.5 | **EQUIPO TALLERES/CRT** | 90d | 2024-10-18 | 2025-01-30 |  | 0d | 7,692.16 | 06.02.05 |
| 768 | 1.7.2.5.1 | KIT DE DISEÑO O TRABAJO | 90d | 2024-10-18 | 2025-01-30 | 766SS | 0d | 356.16 | 06.02.05.01 |
| 769 | 1.7.2.5.2 | KIT DE MAPAS DE PERÚ | 90d | 2024-10-18 | 2025-01-30 | 768SS | 0d | 1,400 | 06.02.05.02 |
| 770 | 1.7.2.5.3 | KIT DE MAPAS DE CONTINENTES | 90d | 2024-10-18 | 2025-01-30 | 769SS | 0d | 1,568 | 06.02.05.03 |
| 771 | 1.7.2.5.4 | KIT SISTEMA SOLAR | 90d | 2024-10-18 | 2025-01-30 | 770SS | 0d | 1,400 | 06.02.05.04 |
| 772 | 1.7.2.5.5 | GLOBO TERRÁQUEO FÍSICO POLÍTICO CON PLANISFERIO | 90d | 2024-10-18 | 2025-01-30 | 771SS | 0d | 1,568 | 06.02.05.05 |
| 773 | 1.7.2.5.6 | EQUIPO DE CONSTRUCCIÓN GEOMÉTRICA | 90d | 2024-10-18 | 2025-01-30 | 772SS | 0d | 1,400 | 06.02.05.06 |
| 774 | 1.7.2.6 | **EQUIPO EDUCACION FISICA** | 90d | 2024-10-18 | 2025-01-30 |  | 0d | 145,192 | 06.02.06 |
| 775 | 1.7.2.6.1 | PARANTES CON SISTEMA TELESCOPICO | 90d | 2024-10-18 | 2025-01-30 | 773SS | 0d | 12,992 | 06.02.06.01 |
| 776 | 1.7.2.6.2 | NET DE VOLEY | 90d | 2024-10-18 | 2025-01-30 | 775SS | 0d | 1,600 | 06.02.06.02 |
| 777 | 1.7.2.6.3 | SILBATOS | 90d | 2024-10-18 | 2025-01-30 | 776SS | 0d | 2,352 | 06.02.06.03 |
| 778 | 1.7.2.6.4 | PELOTAS DE BÁSQUET N°7 | 90d | 2024-10-18 | 2025-01-30 | 777SS | 0d | 20,400 | 06.02.06.04 |
| 779 | 1.7.2.6.5 | TABURETES DE MADERA | 90d | 2024-10-18 | 2025-01-30 | 778SS | 0d | 15,052.8 | 06.02.06.05 |
| 780 | 1.7.2.6.6 | CRONÓMETRO DIGITAL A PILAS | 90d | 2024-10-18 | 2025-01-30 | 779SS | 0d | 5,712 | 06.02.06.06 |
| 781 | 1.7.2.6.7 | PELOTAS DE VOLEY | 90d | 2024-10-18 | 2025-01-30 | 780SS | 0d | 15,120 | 06.02.06.07 |
| 782 | 1.7.2.6.8 | PELOTAS DE FÚTBOL N°5 | 90d | 2024-10-18 | 2025-01-30 | 781SS | 0d | 13,440 | 06.02.06.08 |
| 783 | 1.7.2.6.9 | BALANZA ELECTRÓNICA | 90d | 2024-10-18 | 2025-01-30 | 782SS | 0d | 1,523.2 | 06.02.06.09 |
| 784 | 1.7.2.6.10 | COLCHONETAS | 90d | 2024-10-18 | 2025-01-30 | 783SS | 0d | 57,000 | 06.02.06.10 |
| 785 | 1.7.2.7 | **EQUIPAMIENTO DE BANDA** | 90d | 2024-10-18 | 2025-01-30 |  | 0d | 115,587.2 | 06.02.07 |
| 786 | 1.7.2.7.1 | TROMPETA | 90d | 2024-10-18 | 2025-01-30 | 784SS | 0d | 10,427.2 | 06.02.07.01 |
| 787 | 1.7.2.7.2 | BOMBO | 90d | 2024-10-18 | 2025-01-30 | 786SS | 0d | 4,500 | 06.02.07.02 |
| 788 | 1.7.2.7.3 | TAROLA | 90d | 2024-10-18 | 2025-01-30 | 787SS | 0d | 25,500 | 06.02.07.03 |
| 789 | 1.7.2.7.4 | PLATILLOS | 90d | 2024-10-18 | 2025-01-30 | 788SS | 0d | 17,920 | 06.02.07.04 |
| 790 | 1.7.2.7.5 | PANDERETA | 90d | 2024-10-18 | 2025-01-30 | 789SS | 0d | 1,600 | 06.02.07.05 |
| 791 | 1.7.2.7.6 | BAJO DE VIENTO | 90d | 2024-10-18 | 2025-01-30 | 790SS | 0d | 7,840 | 06.02.07.06 |
| 792 | 1.7.2.7.7 | LIRA ROMA | 90d | 2024-10-18 | 2025-01-30 | 791SS | 0d | 3,000 | 06.02.07.07 |
| 793 | 1.7.2.7.8 | TROMBON DE VARA | 90d | 2024-10-18 | 2025-01-30 | 792SS | 0d | 5,800 | 06.02.07.08 |
| 794 | 1.7.2.7.9 | CORNETA | 90d | 2024-10-18 | 2025-01-30 | 793SS | 0d | 3,200 | 06.02.07.09 |
| 795 | 1.7.2.7.10 | CLARINETE | 90d | 2024-10-18 | 2025-01-30 | 794SS | 0d | 18,000 | 06.02.07.10 |
| 796 | 1.7.2.7.11 | SAXO | 90d | 2024-10-18 | 2025-01-30 | 795SS | 0d | 15,000 | 06.02.07.11 |
| 797 | 1.7.2.7.12 | TAMBORES | 90d | 2024-10-18 | 2025-01-30 | 796SS | 0d | 2,800 | 06.02.07.12 |

| ID | WBS | Task | Type | Duration | Start | Finish | Predecessors | Total slack | Cost | Text1 |
| --- | --- | --- | --- | --- | --- | --- | --- | --- | --- | --- |
| 798 | 1.7.2.8 | **EQUIPO COMPLEMENTARIO** |  | 90d | 2024-10-18 | 2025-01-30 |  | 0d | 15,761.85 | 06.02.08 |
| 799 | 1.7.2.8.1 | EXTINTOR |  | 90d | 2024-10-18 | 2025-01-30 | 797SS | 0d | 358.4 | 06.02.08.01 |
| 800 | 1.7.2.8.2 | COCINA INDUSTRIAL 6 HORNILLAS |  | 90d | 2024-10-18 | 2025-01-30 | 799SS | 0d | 6,160 | 06.02.08.02 |
| 801 | 1.7.2.8.3 | CONGELADORA |  | 90d | 2024-10-18 | 2025-01-30 | 800SS | 0d | 2,033.05 | 06.02.08.03 |
| 802 | 1.7.2.8.4 | REFRIGERADORA |  | 90d | 2024-10-18 | 2025-01-30 | 801SS | 0d | 2,280 | 06.02.08.04 |
| 803 | 1.7.2.8.5 | FRIGO BAR |  | 90d | 2024-10-18 | 2025-01-30 | 802SS | 0d | 873.6 | 06.02.08.05 |
| 804 | 1.7.2.8.6 | LICUADORA |  | 90d | 2024-10-18 | 2025-01-30 | 803SS | 0d | 2,500 | 06.02.08.06 |
| 805 | 1.7.2.8.7 | BALÓN DE GAS Y ACCESORIOS |  | 90d | 2024-10-18 | 2025-01-30 | 804SS | 0d | 280 | 06.02.08.07 |
| 806 | 1.7.2.8.8 | MICROONDAS |  | 90d | 2024-10-18 | 2025-01-30 | 805SS | 0d | 1,276.8 | 06.02.08.08 |
| 807 | 1.7.3 | **TRANSPORTE DE MOBILIARIO Y EQUIPAMIENTO** |  | 90d | 2024-10-18 | 2025-01-30 |  | 0d | 44,800 | 06.03 |
| 808 | 1.7.3.1 | TRANSPORTE DE MOBILIARIO Y EQUIPAMIENTO A LA OBRA |  | 90d | 2024-10-18 | 2025-01-30 | 806SS | 0d | 44,800 | 06.03.01 |
| 809 | 1.8 | FIN DEL PROYECTO | milestone | 0d | 2025-01-30 | 2025-01-30 | 134, 808 | 0d |  |  |
